# Libra Training Manual

How a schedule from MS Project changed from version to version. A marks actual dates.

## Version 1 (saved 2003-10-22, file Outline.mpp)

| ID | Task | Duration | Start | Finish | Total float |
| --- | --- | --- | --- | --- | --- |
| 1 | Start Book | 0d | 2005-08-01 | 2005-08-01 | 30d |
| 2 | Research Phase | 9d | 2005-08-01 | 2005-08-11 | 21d |
| 3 | Interview Subject Matter Experts | 2d | 2005-08-01 | 2005-08-02 | 28d |
| 4 | Investigate the software | 5d | 2005-08-01 | 2005-08-05 | 25d |
| 5 | Search the Web | 2d | 2005-08-01 | 2005-08-02 | 28d |
| 6 | Outline Phase | 5d | 2005-08-01 | 2005-08-05 | 25d |
| 7 | Create outline | 3d | 2005-08-01 | 2005-08-03 | 27d |
| 8 | Present to publisher | 1d | 2005-08-01 | 2005-08-01 | 29d |
| 9 | Revise outline | 1d | 2005-08-01 | 2005-08-01 | 29d |
| 10 | Development Phase | 30d | 2005-08-01 | 2005-09-12 | 0d |
| 11 | Write content | 25d | 2005-08-01 | 2005-09-02 | 5d |
| 12 | Add graphics | 5d | 2005-08-01 | 2005-08-05 | 25d |
| 13 | Edit Phase | 5d | 2005-08-01 | 2005-08-05 | 25d |
| 14 | Check grammar, spelling, and proofread | 3d | 2005-08-01 | 2005-08-03 | 27d |
| 15 | Check for technical accuracy | 2d | 2005-08-01 | 2005-08-02 | 28d |
| 16 | Review Phase | 2d | 2005-08-01 | 2005-08-02 | 28d |
| 17 | Approve editing changes | 1d | 2005-08-01 | 2005-08-01 | 29d |
| 18 | Meet with editor | 1d | 2005-08-01 | 2005-08-01 | 29d |
| 19 | Print Phase | 3d | 2005-08-01 | 2005-08-03 | 27d |
| 20 | Print proof | 1d | 2005-08-01 | 2005-08-01 | 29d |
| 21 | Review proof | 1d | 2005-08-01 | 2005-08-01 | 29d |
| 22 | Print final | 1d | 2005-08-01 | 2005-08-01 | 29d |
| 23 | Book Complete | 0d | 2005-08-01 | 2005-08-01 | 30d |

## Version 2 (saved 2003-10-22, file Relationships.mpp)

Last finish 2005-09-12 → 2005-09-02 (-10d).

Removed: 6 Outline Phase; 7 Create outline; 8 Present to publisher; 9 Revise outline; 16 Review Phase; 17 Approve editing changes; 18 Meet with editor

Changed:

| ID | Task | Finish | Duration | Total float |
| --- | --- | --- | --- | --- |
| 2 | **Research Phase** | 2005-08-11 → 2005-08-05 (-6d) | 9d → 5d | 21d → 20d |
| 6 | **Development Phase** | 2005-09-12 → 2005-09-02 (-10d) | 30d → 25d |  |
| 9 | **Edit Phase** | 2005-08-05 → 2005-08-03 (-2d) | 5d → 3d | 25d → 22d |
| 12 | **Print Phase** | 2005-08-03 → 2005-08-01 (-2d) | 3d → 1d | 27d → 24d |

## Version 3 (saved 2003-10-22, file Link.mpp)

Last finish 2005-09-02 → 2005-10-14 (+42d).

Added:

| ID | Task | Duration | Start | Finish | Predecessors |
| --- | --- | --- | --- | --- | --- |
| 6 | **Outline Phase** | 5d | 2005-08-12 | 2005-08-18 |  |
| 7 | Create outline | 3d | 2005-08-12 | 2005-08-16 | 5 |
| 8 | Present to publisher | 1d | 2005-08-17 | 2005-08-17 | 7 |
| 9 | Revise outline | 1d | 2005-08-18 | 2005-08-18 | 8 |
| 16 | **Review Phase** | 2d | 2005-10-10 | 2005-10-11 |  |
| 17 | Approve editing changes | 1d | 2005-10-10 | 2005-10-10 | 15 |
| 18 | Meet with editor | 1d | 2005-10-11 | 2005-10-11 | 17 |

Changed:

| ID | Task | Start | Finish | Duration | Total float | Predecessors |
| --- | --- | --- | --- | --- | --- | --- |
| 2 | **Research Phase** |  | 2005-08-05 → 2005-08-11 (+6d) | 5d → 9d | 20d → 0d |  |
| 3 | Interview Subject Matter Experts |  |  |  | 23d → 0d | none → 1 |
| 4 | Investigate the software | 2005-08-01 → 2005-08-03 (+2d) | 2005-08-05 → 2005-08-09 (+4d) |  | 20d → 0d | none → 3 |
| 5 | Search the Web | 2005-08-01 → 2005-08-10 (+9d) | 2005-08-02 → 2005-08-11 (+9d) |  | 23d → 0d | none → 4 |
| 10 | **Development Phase** | 2005-08-01 → 2005-08-19 (+18d) | 2005-09-02 → 2005-09-30 (+28d) | 25d → 30d |  |  |
| 11 | Write content | 2005-08-01 → 2005-08-19 (+18d) | 2005-09-02 → 2005-09-23 (+21d) |  |  | none → 9 |
| 12 | Add graphics | 2005-08-01 → 2005-09-26 (+56d) | 2005-08-05 → 2005-09-30 (+56d) |  | 20d → 0d | none → 11 |
| 13 | **Edit Phase** | 2005-08-01 → 2005-10-03 (+63d) | 2005-08-03 → 2005-10-07 (+65d) | 3d → 5d | 22d → 0d |  |
| 14 | Check grammar, spelling, and proofread | 2005-08-01 → 2005-10-03 (+63d) | 2005-08-03 → 2005-10-05 (+63d) |  | 22d → 0d | none → 12 |
| 15 | Check for technical accuracy | 2005-08-01 → 2005-10-06 (+66d) | 2005-08-02 → 2005-10-07 (+66d) |  | 23d → 0d | none → 14 |
| 19 | **Print Phase** | 2005-08-01 → 2005-10-12 (+72d) | 2005-08-01 → 2005-10-14 (+74d) | 1d → 3d | 24d → 0d |  |
| 20 | Print proof | 2005-08-01 → 2005-10-12 (+72d) | 2005-08-01 → 2005-10-12 (+72d) |  | 24d → 0d | none → 18 |
| 21 | Review proof | 2005-08-01 → 2005-10-13 (+73d) | 2005-08-01 → 2005-10-13 (+73d) |  | 24d → 0d | none → 20 |
| 22 | Print final | 2005-08-01 → 2005-10-14 (+74d) | 2005-08-01 → 2005-10-14 (+74d) |  | 24d → 0d | none → 21 |
| 23 | Book Complete | 2005-08-01 → 2005-10-14 (+74d) | 2005-08-01 → 2005-10-14 (+74d) |  | 25d → 0d | none → 22 |

## Version 4 (saved 2003-10-22, file Link Backup.mpp)

Last finish 2005-10-14 → 2005-10-12 (-2d).

Added:

| ID | Task | Duration | Start | Finish | Predecessors |
| --- | --- | --- | --- | --- | --- |
| 9 | Review with Subject Matter Expert | 1d | 2005-08-17 | 2005-08-17 | 8SS |

Changed:

| ID | Task | Start | Finish | Duration | Predecessors |
| --- | --- | --- | --- | --- | --- |
| 10 | Revise outline |  |  |  | 8 → 9 |
| 14 | **Edit Phase** |  | 2005-10-07 → 2005-10-05 (-2d) | 5d → 3d |  |
| 16 | Check for technical accuracy | 2005-10-06 → 2005-10-04 (-2d) | 2005-10-07 → 2005-10-05 (-2d) |  | 15 → 15FF |
| 17 | **Review Phase** | 2005-10-10 → 2005-10-06 (-4d) | 2005-10-11 → 2005-10-07 (-4d) |  |  |
| 18 | Approve editing changes | 2005-10-10 → 2005-10-06 (-4d) | 2005-10-10 → 2005-10-06 (-4d) |  |  |
| 19 | Meet with editor | 2005-10-11 → 2005-10-07 (-4d) | 2005-10-11 → 2005-10-07 (-4d) |  |  |
| 20 | **Print Phase** | 2005-10-12 → 2005-10-10 (-2d) | 2005-10-14 → 2005-10-12 (-2d) |  |  |
| 21 | Print proof | 2005-10-12 → 2005-10-10 (-2d) | 2005-10-12 → 2005-10-10 (-2d) |  |  |
| 22 | Review proof | 2005-10-13 → 2005-10-11 (-2d) | 2005-10-13 → 2005-10-11 (-2d) |  |  |
| 23 | Print final | 2005-10-14 → 2005-10-12 (-2d) | 2005-10-14 → 2005-10-12 (-2d) |  |  |
| 24 | Book Complete | 2005-10-14 → 2005-10-12 (-2d) | 2005-10-14 → 2005-10-12 (-2d) |  |  |

## Version 5 (saved 2003-10-22, file Constraints.mpp)

Last finish 2005-10-12 → 2005-10-10 (-2d).

Changed:

| ID | Task | Start | Finish | Predecessors |
| --- | --- | --- | --- | --- |
| 14 | **Edit Phase** | 2005-10-03 → 2005-09-28 (-5d) | 2005-10-05 → 2005-10-03 (-2d) |  |
| 15 | Check grammar, spelling, and proofread | 2005-10-03 → 2005-09-28 (-5d) | 2005-10-05 → 2005-10-03 (-2d) | 13 → 13FS-5% |
| 16 | Check for technical accuracy | 2005-10-04 → 2005-09-29 (-5d) | 2005-10-05 → 2005-10-03 (-2d) |  |
| 17 | **Review Phase** | 2005-10-06 → 2005-10-03 (-3d) | 2005-10-07 → 2005-10-05 (-2d) |  |
| 18 | Approve editing changes | 2005-10-06 → 2005-10-03 (-3d) | 2005-10-06 → 2005-10-04 (-2d) |  |
| 19 | Meet with editor | 2005-10-07 → 2005-10-04 (-3d) | 2005-10-07 → 2005-10-05 (-2d) |  |
| 20 | **Print Phase** | 2005-10-10 → 2005-10-05 (-5d) | 2005-10-12 → 2005-10-10 (-2d) |  |
| 21 | Print proof | 2005-10-10 → 2005-10-05 (-5d) | 2005-10-10 → 2005-10-06 (-4d) |  |
| 22 | Review proof | 2005-10-11 → 2005-10-06 (-5d) | 2005-10-11 → 2005-10-07 (-4d) |  |
| 23 | Print final | 2005-10-12 → 2005-10-07 (-5d) | 2005-10-12 → 2005-10-10 (-2d) |  |
| 24 | Book Complete | 2005-10-12 → 2005-10-10 (-2d) | 2005-10-12 → 2005-10-10 (-2d) |  |

## Version 6 (saved 2003-10-23, file Resources.mpp)

Last finish 2005-10-10 → 2005-10-14 (+4d).

Changed:

| ID | Task | Start | Finish | Duration | Total float | Predecessors | Other |
| --- | --- | --- | --- | --- | --- | --- | --- |
| 3 | Interview Subject Matter Experts |  |  |  | 0d → 2d | 1 → none |  |
| 6 | **Outline Phase** |  | 2005-08-18 → 2005-08-22 (+4d) | 5d → 7d |  |  |  |
| 9 | Review with Subject Matter Expert | 2005-08-17 → 2005-08-19 (+2d) | 2005-08-17 → 2005-08-19 (+2d) |  |  |  | constraint none → start no earlier than 2005-08-19 |
| 10 | Revise outline | 2005-08-18 → 2005-08-22 (+4d) | 2005-08-18 → 2005-08-22 (+4d) |  |  |  |  |
| 11 | **Development Phase** | 2005-08-19 → 2005-08-23 (+4d) | 2005-09-30 → 2005-10-04 (+4d) |  |  |  |  |
| 12 | Write content | 2005-08-19 → 2005-08-23 (+4d) | 2005-09-23 → 2005-09-27 (+4d) |  |  |  |  |
| 13 | Add graphics | 2005-09-26 → 2005-09-28 (+2d) | 2005-09-30 → 2005-10-04 (+4d) |  |  |  |  |
| 14 | **Edit Phase** | 2005-09-28 → 2005-10-05 (+7d) | 2005-10-03 → 2005-10-07 (+4d) |  |  |  |  |
| 15 | Check grammar, spelling, and proofread | 2005-09-28 → 2005-10-05 (+7d) | 2005-10-03 → 2005-10-07 (+4d) |  |  | 13FS-5% → 13 |  |
| 16 | Check for technical accuracy | 2005-09-29 → 2005-10-06 (+7d) | 2005-10-03 → 2005-10-07 (+4d) |  |  |  |  |
| 17 | **Review Phase** | 2005-10-03 → 2005-10-10 (+7d) | 2005-10-05 → 2005-10-11 (+6d) |  |  |  |  |
| 18 | Approve editing changes | 2005-10-03 → 2005-10-10 (+7d) | 2005-10-04 → 2005-10-10 (+6d) |  |  |  |  |
| 19 | Meet with editor | 2005-10-04 → 2005-10-11 (+7d) | 2005-10-05 → 2005-10-11 (+6d) |  |  |  |  |
| 20 | **Print Phase** | 2005-10-05 → 2005-10-12 (+7d) | 2005-10-10 → 2005-10-14 (+4d) |  |  |  |  |
| 21 | Print proof | 2005-10-05 → 2005-10-12 (+7d) | 2005-10-06 → 2005-10-12 (+6d) |  |  |  |  |
| 22 | Review proof | 2005-10-06 → 2005-10-13 (+7d) | 2005-10-07 → 2005-10-13 (+6d) |  |  |  |  |
| 23 | Print final | 2005-10-07 → 2005-10-14 (+7d) | 2005-10-10 → 2005-10-14 (+4d) |  |  |  |  |
| 24 | Book Complete | 2005-10-10 → 2005-10-14 (+4d) | 2005-10-10 → 2005-10-14 (+4d) |  |  |  |  |

## Version 7 (saved 2003-10-23, file Allocations.mpp)

Last finish 2005-10-14 → 2005-10-10 (-4d).

Changed:

| ID | Task | Start | Finish | Duration | Total float | Other |
| --- | --- | --- | --- | --- | --- | --- |
| 2 | **Research Phase** |  | 2005-08-11 → 2005-08-10 (-1d) | 9d → 8d | 2d → 3d |  |
| 3 | Interview Subject Matter Experts |  |  |  | 2d → 3d | resources none → Writer 1; Project Manager 1 |
| 4 | Investigate the software |  |  |  | 2d → 3d | resources none → Writer 1 |
| 5 | Search the Web |  | 2005-08-11 → 2005-08-10 (-1d) | 2d → 1d | 2d → 3d | resources none → Writer 1; Staff Assistant 1 |
| 6 | **Outline Phase** | 2005-08-12 → 2005-08-11 (-1d) |  | 7d → 7.5d |  |  |
| 7 | Create outline | 2005-08-12 → 2005-08-11 (-1d) | 2005-08-16 → 2005-08-15 (-1d) |  | 2d → 3d | resources none → Writer 1 |
| 8 | Present to publisher | 2005-08-17 → 2005-08-16 (-1d) | 2005-08-17 → 2005-08-16 (-1d) | 1d → 0.2d | 2d → 3d | resources none → Project Manager 1 [50%]; Writer 1; Publisher 1 |
| 9 | Review with Subject Matter Expert |  |  | 1d → 0.5d |  | resources none → Writer 1; Subject Matter Expert |
| 10 | Revise outline | 2005-08-22 → 2005-08-19 (-3d) |  |  |  | resources none → Writer 1 |
| 11 | **Development Phase** | 2005-08-23 → 2005-08-22 (-1d) | 2005-10-04 → 2005-09-29 (-5d) | 30d → 27.5d |  |  |
| 12 | Write content | 2005-08-23 → 2005-08-22 (-1d) |  |  |  | resources none → Writer 1 |
| 13 | Add graphics | 2005-09-28 → 2005-09-27 (-1d) | 2005-10-04 → 2005-09-29 (-5d) | 5d → 2.5d |  | resources none → Artist 1; Staff Assistant 1 |
| 14 | **Edit Phase** | 2005-10-05 → 2005-09-30 (-5d) | 2005-10-07 → 2005-10-04 (-3d) |  |  |  |
| 15 | Check grammar, spelling, and proofread | 2005-10-05 → 2005-09-30 (-5d) | 2005-10-07 → 2005-10-04 (-3d) |  |  | resources none → Editor 1 |
| 16 | Check for technical accuracy | 2005-10-06 → 2005-10-04 (-2d) | 2005-10-07 → 2005-10-04 (-3d) | 2d → 1d |  | resources none → Editor 1; Subject Matter Expert |
| 17 | **Review Phase** | 2005-10-10 → 2005-10-05 (-5d) | 2005-10-11 → 2005-10-06 (-5d) | 2d → 1.5d |  |  |
| 18 | Approve editing changes | 2005-10-10 → 2005-10-05 (-5d) | 2005-10-10 → 2005-10-05 (-5d) |  |  | resources none → Writer 1 |
| 19 | Meet with editor | 2005-10-11 → 2005-10-06 (-5d) | 2005-10-11 → 2005-10-06 (-5d) | 1d → 0.5d |  | resources none → Writer 1; Editor 1 |
| 20 | **Print Phase** | 2005-10-12 → 2005-10-06 (-6d) | 2005-10-14 → 2005-10-10 (-4d) | 3d → 1.83d |  |  |
| 21 | Print proof | 2005-10-12 → 2005-10-06 (-6d) | 2005-10-12 → 2005-10-06 (-6d) | 1d → 0.5d |  | resources none → Printer 1; Plain Paper |
| 22 | Review proof | 2005-10-13 → 2005-10-07 (-6d) | 2005-10-13 → 2005-10-07 (-6d) | 1d → 0.33d |  | resources none → Writer 1; Editor 1; Project Manager 1 |
| 23 | Print final | 2005-10-14 → 2005-10-07 (-7d) | 2005-10-14 → 2005-10-10 (-4d) |  |  | resources none → Printer 1; Glossy Paper |
| 24 | Book Complete | 2005-10-14 → 2005-10-10 (-4d) | 2005-10-14 → 2005-10-10 (-4d) |  |  |  |

## Version 8 (saved 2003-10-23, file Finalize.mpp)

Last finish 2005-10-10 → 2005-10-12 (+2d).

Changed:

| ID | Task | Start | Finish | Duration | Predecessors |
| --- | --- | --- | --- | --- | --- |
| 14 | **Edit Phase** |  | 2005-10-04 → 2005-10-06 (+2d) | 3d → 5d |  |
| 16 | Check for technical accuracy | 2005-10-04 → 2005-10-06 (+2d) | 2005-10-04 → 2005-10-06 (+2d) |  | 15FF → 15 |
| 17 | **Review Phase** | 2005-10-05 → 2005-10-07 (+2d) | 2005-10-06 → 2005-10-10 (+4d) |  |  |
| 18 | Approve editing changes | 2005-10-05 → 2005-10-07 (+2d) | 2005-10-05 → 2005-10-07 (+2d) |  |  |
| 19 | Meet with editor | 2005-10-06 → 2005-10-10 (+4d) | 2005-10-06 → 2005-10-10 (+4d) |  |  |
| 20 | **Print Phase** | 2005-10-06 → 2005-10-10 (+4d) | 2005-10-10 → 2005-10-12 (+2d) |  |  |
| 21 | Print proof | 2005-10-06 → 2005-10-10 (+4d) | 2005-10-06 → 2005-10-10 (+4d) |  |  |
| 22 | Review proof | 2005-10-07 → 2005-10-11 (+4d) | 2005-10-07 → 2005-10-11 (+4d) |  |  |
| 23 | Print final | 2005-10-07 → 2005-10-11 (+4d) | 2005-10-10 → 2005-10-12 (+2d) |  |  |
| 24 | Book Complete | 2005-10-10 → 2005-10-12 (+2d) | 2005-10-10 → 2005-10-12 (+2d) |  |  |

## Version 9 (saved 2003-10-23, file Requirements.mpp)

Last finish 2005-10-12 → 2005-09-27 (-15d).

Added:

| ID | Task | Duration | Start | Finish | Predecessors | Resources |
| --- | --- | --- | --- | --- | --- | --- |
| 13 | Write Lessons 6 - 10 | 12.5d | 2005-08-22 | 2005-09-08 | 12SS |  |
| 14 | Write Appendix A | 3d | 2005-09-09 | 2005-09-13 | 13 | Writer 1 |

Changed:

| ID | Task | Start | Finish | Duration | Predecessors | Other |
| --- | --- | --- | --- | --- | --- | --- |
| 11 | **Development Phase** |  | 2005-09-29 → 2005-09-16 (-13d) | 27.5d → 18d |  |  |
| 12 | Write Lessons 1 - 5 |  | 2005-09-27 → 2005-09-08 (-19d) | 25d → 12.5d |  | was named Write content |
| 15 | Add graphics | 2005-09-27 → 2005-09-14 (-13d) | 2005-09-29 → 2005-09-16 (-13d) |  | 12 → 14 |  |
| 16 | **Edit Phase** | 2005-09-30 → 2005-09-16 (-14d) | 2005-10-06 → 2005-09-21 (-15d) | 5d → 3.5d |  |  |
| 17 | Check grammar, spelling, and proofread | 2005-09-30 → 2005-09-16 (-14d) | 2005-10-04 → 2005-09-19 (-15d) | 3d → 1.5d |  | resources Editor 1 → Editor 1; Editor 2 |
| 18 | Check for technical accuracy | 2005-10-06 → 2005-09-21 (-15d) | 2005-10-06 → 2005-09-21 (-15d) |  |  |  |
| 19 | **Review Phase** | 2005-10-07 → 2005-09-22 (-15d) | 2005-10-10 → 2005-09-23 (-17d) |  |  |  |
| 20 | Approve editing changes | 2005-10-07 → 2005-09-22 (-15d) | 2005-10-07 → 2005-09-22 (-15d) |  |  |  |
| 21 | Meet with editor | 2005-10-10 → 2005-09-23 (-17d) | 2005-10-10 → 2005-09-23 (-17d) |  |  |  |
| 22 | **Print Phase** | 2005-10-10 → 2005-09-23 (-17d) | 2005-10-12 → 2005-09-27 (-15d) |  |  |  |
| 23 | Print proof | 2005-10-10 → 2005-09-23 (-17d) | 2005-10-10 → 2005-09-23 (-17d) |  |  |  |
| 24 | Review proof | 2005-10-11 → 2005-09-26 (-15d) | 2005-10-11 → 2005-09-26 (-15d) |  |  |  |
| 25 | Print final | 2005-10-11 → 2005-09-26 (-15d) | 2005-10-12 → 2005-09-27 (-15d) |  |  |  |
| 26 | Book Complete | 2005-10-12 → 2005-09-27 (-15d) | 2005-10-12 → 2005-09-27 (-15d) |  |  |  |

## Version 10 (saved 2003-11-03, file CSS Week 1.mpp)

Last finish 2005-09-27 → 2005-10-19 (+22d).

Removed: 13 Write Lessons 6 - 10; 14 Write Appendix A

Changed:

| ID | Task | Start | Finish | Duration | Total float | Predecessors | Other |
| --- | --- | --- | --- | --- | --- | --- | --- |
| 1 | Start Book |  |  |  | 40.33d → 57d |  | resources none → Project Manager 1; Writer 1; baseline start none → 2005-08-01; baseline finish none → 2005-08-01 |
| 2 | **Research Phase** |  |  |  |  |  | baseline start none → 2005-08-01; baseline finish none → 2005-08-10 |
| 3 | Interview Subject Matter Expert |  |  |  |  |  | was named Interview Subject Matter Experts; resources Writer 1; Project Manager 1 → Project Manager 1; Writer 1; Subject Matter Expert 1; baseline start none → 2005-08-01; baseline finish none → 2005-08-02 |
| 4 | Investigate the software |  | 2005-08-09 → 2005-08-08 (-1d) | 5d → 4d |  |  | baseline start none → 2005-08-03; baseline finish none → 2005-08-08 |
| 5 | Search the Web | 2005-08-10 → 2005-08-09 (-1d) |  | 1d → 2d |  |  | baseline start none → 2005-08-09; baseline finish none → 2005-08-10 |
| 6 | **Outline Phase** |  | 2005-08-22 → 2005-08-23 (+1d) | 7.5d → 9d |  |  | baseline start none → 2005-08-11; baseline finish none → 2005-08-23 |
| 7 | Create outline |  |  |  |  |  | baseline start none → 2005-08-11; baseline finish none → 2005-08-15 |
| 8 | Present to publisher |  |  | 0.2d → 1d |  |  | resources Project Manager 1 [50%]; Writer 1; Publisher 1 → Writer 1; Project Manager 1; Publisher 1; baseline start none → 2005-08-16; baseline finish none → 2005-08-16 |
| 9 | Review with Subject Matter Expert |  | 2005-08-19 → 2005-08-22 (+3d) | 0.5d → 2d |  |  | resources Writer 1; Subject Matter Expert → Writer 1; Subject Matter Expert 1; baseline start none → 2005-08-19; baseline finish none → 2005-08-22 |
| 10 | Revise outline | 2005-08-19 → 2005-08-23 (+4d) | 2005-08-22 → 2005-08-23 (+1d) |  |  |  | baseline start none → 2005-08-23; baseline finish none → 2005-08-23 |
| 11 | **Development Phase** | 2005-08-22 → 2005-08-24 (+2d) | 2005-09-16 → 2005-10-05 (+19d) | 18d → 30d |  |  | baseline start none → 2005-08-24; baseline finish none → 2005-10-05 |
| 12 | Write content | 2005-08-22 → 2005-08-24 (+2d) | 2005-09-08 → 2005-09-28 (+20d) | 12.5d → 25d |  |  | was named Write Lessons 1 - 5; baseline start none → 2005-08-24; baseline finish none → 2005-09-28 |
| 13 | Add graphics | 2005-09-14 → 2005-09-29 (+15d) | 2005-09-16 → 2005-10-05 (+19d) | 2.5d → 5d |  | Write Appendix A → 12 | baseline start none → 2005-09-29; baseline finish none → 2005-10-05 |
| 14 | **Edit Phase** | 2005-09-16 → 2005-10-06 (+20d) | 2005-09-21 → 2005-10-12 (+21d) | 3.5d → 5d |  |  | baseline start none → 2005-10-06; baseline finish none → 2005-10-12 |
| 15 | Check grammar, spelling, and proofread | 2005-09-16 → 2005-10-06 (+20d) | 2005-09-19 → 2005-10-10 (+21d) | 1.5d → 3d |  |  | resources Editor 1; Editor 2 → Editor 1; baseline start none → 2005-10-06; baseline finish none → 2005-10-10 |
| 16 | Check for technical accuracy | 2005-09-21 → 2005-10-11 (+20d) | 2005-09-21 → 2005-10-12 (+21d) | 1d → 2d |  | 15 → 15FF | resources Editor 1; Subject Matter Expert → Editor 1; Subject Matter Expert 1; baseline start none → 2005-10-11; baseline finish none → 2005-10-12 |
| 17 | **Review Phase** | 2005-09-22 → 2005-10-13 (+21d) | 2005-09-23 → 2005-10-14 (+21d) | 1.5d → 2d |  |  | baseline start none → 2005-10-13; baseline finish none → 2005-10-14 |
| 18 | Approve editing changes | 2005-09-22 → 2005-10-13 (+21d) | 2005-09-22 → 2005-10-13 (+21d) |  |  |  | baseline start none → 2005-10-13; baseline finish none → 2005-10-13 |
| 19 | Meet with editor | 2005-09-23 → 2005-10-14 (+21d) | 2005-09-23 → 2005-10-14 (+21d) | 0.5d → 1d |  |  | baseline start none → 2005-10-14; baseline finish none → 2005-10-14 |
| 20 | **Print Phase** | 2005-09-23 → 2005-10-17 (+24d) | 2005-09-27 → 2005-10-19 (+22d) | 1.83d → 3d |  |  | baseline start none → 2005-10-17; baseline finish none → 2005-10-19 |
| 21 | Print proof | 2005-09-23 → 2005-10-17 (+24d) | 2005-09-23 → 2005-10-17 (+24d) | 0.5d → 1d |  |  | resources Printer 1; Plain Paper → Printer 1; Plain paper; baseline start none → 2005-10-17; baseline finish none → 2005-10-17 |
| 22 | Review proof | 2005-09-26 → 2005-10-18 (+22d) | 2005-09-26 → 2005-10-18 (+22d) | 0.33d → 1d |  |  | baseline start none → 2005-10-18; baseline finish none → 2005-10-18 |
| 23 | Print final | 2005-09-26 → 2005-10-19 (+23d) | 2005-09-27 → 2005-10-19 (+22d) |  |  |  | resources Printer 1; Glossy Paper → Printer 1; Glossy paper; baseline start none → 2005-10-19; baseline finish none → 2005-10-19 |
| 24 | Book Complete | 2005-09-27 → 2005-10-19 (+22d) | 2005-09-27 → 2005-10-19 (+22d) |  |  |  | resources none → Project Manager 1; Writer 1; baseline start none → 2005-10-19; baseline finish none → 2005-10-19 |

## Version 11 (saved 2003-11-03, file CSS Week 2.mpp)

Last finish stays 2005-10-19. Complete tasks 0 → 3.

Changed:

| ID | Task | Start | Finish | Duration | Complete | Total float |
| --- | --- | --- | --- | --- | --- | --- |
| 1 | Start Book | 2005-08-01 A | 2005-08-01 A |  | 0% → 100% | 57d → none |
| 2 | **Research Phase** | 2005-08-01 A | 2005-08-10 → 2005-08-09 (-1d) | 8d → 7d | 0% → 71% | 3d → 4d |
| 3 | Interview Subject Matter Expert | 2005-08-01 A | 2005-08-02 → 2005-08-01 A (-1d) | 2d → 1d | 0% → 100% | 3d → none |
| 4 | Investigate the software | 2005-08-03 → 2005-08-02 A (-1d) | 2005-08-08 → 2005-08-05 A (-3d) |  | 0% → 100% | 3d → none |
| 5 | Search the Web | 2005-08-09 → 2005-08-08 (-1d) | 2005-08-10 → 2005-08-09 (-1d) |  |  | 3d → 4d |
| 6 | **Outline Phase** | 2005-08-11 → 2005-08-10 (-1d) |  | 9d → 10d |  |  |
| 7 | Create outline | 2005-08-11 → 2005-08-10 (-1d) | 2005-08-15 → 2005-08-12 (-3d) |  |  | 3d → 4d |
| 8 | Present to publisher | 2005-08-16 → 2005-08-15 (-1d) | 2005-08-16 → 2005-08-15 (-1d) |  |  | 3d → 4d |

## Version 12 (saved 2003-11-04, file CSS Week 12.mpp)

Last finish stays 2005-10-19. Complete tasks 3 → 14.

Changed:

| ID | Task | Start | Finish | Duration | Complete | Total float |
| --- | --- | --- | --- | --- | --- | --- |
| 2 | **Research Phase** |  | 2005-08-09 → 2005-08-10 A (+1d) | 7d → 8d | 71% → 100% | 4d → none |
| 5 | Search the Web | 2005-08-08 A | 2005-08-09 → 2005-08-10 A (+1d) |  | 0% → 100% | 4d → none |
| 6 | **Outline Phase** | 2005-08-10 → 2005-08-11 A (+1d) | 2005-08-23 → 2005-08-26 A (+3d) | 10d → 12d | 0% → 100% | 0d → none |
| 7 | Create outline | 2005-08-10 → 2005-08-11 A (+1d) | 2005-08-12 → 2005-08-15 A (+3d) |  | 0% → 100% | 4d → none |
| 8 | Present to publisher | 2005-08-15 → 2005-08-18 A (+3d) | 2005-08-15 → 2005-08-19 A (+4d) |  | 0% → 100% | 4d → none |
| 9 | Review with Subject Matter Expert | 2005-08-19 A | 2005-08-22 → 2005-08-23 A (+1d) | 2d → 2.25d | 0% → 100% | 0d → none |
| 10 | Revise outline | 2005-08-23 A | 2005-08-23 → 2005-08-26 A (+3d) | 1d → 3.75d | 0% → 100% | 0d → none |
| 11 | **Development Phase** | 2005-08-24 → 2005-08-29 A (+5d) | 2005-10-05 A | 30d → 27d | 0% → 100% | 0d → none |
| 12 | Write content | 2005-08-24 → 2005-08-29 A (+5d) | 2005-09-28 A | 25d → 22d | 0% → 100% | 0d → none |
| 13 | Add graphics | 2005-09-29 A | 2005-10-05 A |  | 0% → 100% | 0d → none |
| 14 | **Edit Phase** | 2005-10-06 A | 2005-10-12 A |  | 0% → 100% | 0d → none |
| 15 | Check grammar, spelling, and proofread | 2005-10-06 A | 2005-10-10 A |  | 0% → 100% | 0d → none |
| 16 | Check for technical accuracy | 2005-10-11 A | 2005-10-12 A |  | 0% → 100% | 0d → none |
| 17 | **Review Phase** | 2005-10-13 A | 2005-10-14 A |  | 0% → 100% | 0d → none |
| 18 | Approve editing changes | 2005-10-13 A | 2005-10-13 A |  | 0% → 100% | 0d → none |
| 19 | Meet with editor | 2005-10-14 A | 2005-10-14 A |  | 0% → 100% | 0d → none |

## Version 13 (saved 2003-11-05, file HTML Training Manual.mpp)

Last finish 2005-10-19 → 2006-01-24 (+97d). Complete tasks 14 → 0.

Changed:

| ID | Task | Start | Finish | Duration | Complete | Total float | Other |
| --- | --- | --- | --- | --- | --- | --- | --- |
| 1 | Start Book | 2005-08-01 A → 2005-10-31 (+91d) | 2005-08-01 A → 2005-10-31 (+91d) |  | 100% → 0% | none → 57.5d | resources Project Manager 1; Writer 1 → Writer 2; baseline start 2005-08-01 → 2005-10-31; baseline finish 2005-08-01 → 2005-10-31 |
| 2 | **Research Phase** | 2005-08-01 A → 2005-10-31 (+91d) | 2005-08-10 A → 2005-11-09 (+91d) | 8d → 7.5d | 100% → 0% | none → 4d | baseline start 2005-08-01 → 2005-10-31; baseline finish 2005-08-10 → 2005-11-09 |
| 3 | Interview Subject Matter Expert | 2005-08-01 A → 2005-10-31 (+91d) | 2005-08-01 A → 2005-11-01 (+92d) | 1d → 1.5d | 100% → 0% | none → 4d | resources Project Manager 1; Writer 1; Subject Matter Expert 1 → Writer 2; Publisher 2; baseline start 2005-08-01 → 2005-10-31; baseline finish 2005-08-02 → 2005-11-01 |
| 4 | Investigate the software | 2005-08-02 A → 2005-11-01 (+91d) | 2005-08-05 A → 2005-11-07 (+94d) |  | 100% → 0% | none → 4d | resources Writer 1 → Writer 2; baseline start 2005-08-03 → 2005-11-01; baseline finish 2005-08-08 → 2005-11-07 |
| 5 | Search the Web | 2005-08-08 A → 2005-11-07 (+91d) | 2005-08-10 A → 2005-11-09 (+91d) |  | 100% → 0% | none → 4d | resources Writer 1; Staff Assistant 1 → Writer 2; Project Manager 2; baseline start 2005-08-09 → 2005-11-07; baseline finish 2005-08-10 → 2005-11-09 |
| 6 | **Outline Phase** | 2005-08-11 A → 2005-11-09 (+90d) | 2005-08-26 A → 2005-11-29 (+95d) | 12d → 12.5d | 100% → 0% | none → 0.5d | baseline start 2005-08-11 → 2005-11-09; baseline finish 2005-08-23 → 2005-11-29 |
| 7 | Create outline | 2005-08-11 A → 2005-11-09 (+90d) | 2005-08-15 A → 2005-11-14 (+91d) |  | 100% → 0% | none → 4d | resources Writer 1 → Writer 2; baseline start 2005-08-11 → 2005-11-09; baseline finish 2005-08-15 → 2005-11-14 |
| 8 | Present to publisher | 2005-08-18 A → 2005-11-14 (+88d) | 2005-08-19 A → 2005-11-15 (+88d) |  | 100% → 0% | none → 4d | resources Writer 1; Project Manager 1; Publisher 1 → Writer 2; Account Rep 2; baseline start 2005-08-16 → 2005-11-14; baseline finish 2005-08-16 → 2005-11-15 |
| 9 | Review with Subject Matter Expert | 2005-08-19 A → 2005-11-18 (+91d) | 2005-08-23 A → 2005-11-22 (+91d) |  | 100% → 0% | none → 0.5d | constraint start no earlier than 2005-08-19 → start no earlier than 2005-11-18; resources Writer 1; Subject Matter Expert 1 → Writer 2; Publisher 2; baseline start 2005-08-19 → 2005-11-18; baseline finish 2005-08-22 → 2005-11-22 |
| 10 | Revise outline | 2005-08-23 A → 2005-11-22 (+91d) | 2005-08-26 A → 2005-11-29 (+95d) |  | 100% → 0% | none → 0.5d | resources Writer 1 → Writer 2; baseline start 2005-08-23 → 2005-11-22; baseline finish 2005-08-23 → 2005-11-29 |
| 11 | **Development Phase** | 2005-08-29 A → 2005-11-30 (+93d) | 2005-10-05 A → 2006-01-10 (+97d) |  | 100% → 0% | none → 0.5d | baseline start 2005-08-24 → 2005-11-30; baseline finish 2005-10-05 → 2006-01-10 |
| 12 | Write content | 2005-08-29 A → 2005-11-30 (+93d) | 2005-09-28 A → 2006-01-03 (+97d) |  | 100% → 0% | none → 0.5d | resources Writer 1 → Writer 2; baseline start 2005-08-24 → 2005-11-30; baseline finish 2005-09-28 → 2006-01-03 |
| 13 | Add graphics | 2005-09-29 A → 2006-01-03 (+96d) | 2005-10-05 A → 2006-01-10 (+97d) |  | 100% → 0% | none → 0.5d | resources Artist 1; Staff Assistant 1 → Artist 2; Project Manager 2; baseline start 2005-09-29 → 2006-01-03; baseline finish 2005-10-05 → 2006-01-10 |
| 14 | **Edit Phase** | 2005-10-06 A → 2006-01-10 (+96d) | 2005-10-12 A → 2006-01-17 (+97d) |  | 100% → 0% | none → 0d | baseline start 2005-10-06 → 2006-01-10; baseline finish 2005-10-12 → 2006-01-17 |
| 15 | Check grammar, spelling, and proofread | 2005-10-06 A → 2006-01-10 (+96d) | 2005-10-10 A → 2006-01-13 (+95d) |  | 100% → 0% | none → 0.5d | resources Editor 1 → Editor 2; baseline start 2005-10-06 → 2006-01-10; baseline finish 2005-10-10 → 2006-01-13 |
| 16 | Check for technical accuracy | 2005-10-11 A → 2006-01-13 (+94d) | 2005-10-12 A → 2006-01-17 (+97d) |  | 100% → 0% | none → 0d | resources Editor 1; Subject Matter Expert 1 → Editor 2; Publisher 2; baseline start 2005-10-11 → 2006-01-13; baseline finish 2005-10-12 → 2006-01-17 |
| 17 | **Review Phase** | 2005-10-13 A → 2006-01-17 (+96d) | 2005-10-14 A → 2006-01-19 (+97d) |  | 100% → 0% | none → 0d | baseline start 2005-10-13 → 2006-01-17; baseline finish 2005-10-14 → 2006-01-19 |
| 18 | Approve editing changes | 2005-10-13 A → 2006-01-17 (+96d) | 2005-10-13 A → 2006-01-18 (+97d) |  | 100% → 0% | none → 0d | resources Writer 1 → Writer 2; baseline start 2005-10-13 → 2006-01-17; baseline finish 2005-10-13 → 2006-01-18 |
| 19 | Meet with editor | 2005-10-14 A → 2006-01-18 (+96d) | 2005-10-14 A → 2006-01-19 (+97d) |  | 100% → 0% | none → 0d | resources Writer 1; Editor 1 → Writer 2; Editor 2; baseline start 2005-10-14 → 2006-01-18; baseline finish 2005-10-14 → 2006-01-19 |
| 20 | **Print Phase** | 2005-10-17 → 2006-01-19 (+94d) | 2005-10-19 → 2006-01-24 (+97d) | 3d → 3.5d |  |  | baseline start 2005-10-17 → 2006-01-19; baseline finish 2005-10-19 → 2006-01-24 |
| 21 | Print proof | 2005-10-17 → 2006-01-19 (+94d) | 2005-10-17 → 2006-01-20 (+95d) |  |  |  | resources Printer 1; Plain paper → Printer 2; Plain paper; baseline start 2005-10-17 → 2006-01-19; baseline finish 2005-10-17 → 2006-01-20 |
| 22 | Review proof | 2005-10-18 → 2006-01-20 (+94d) | 2005-10-18 → 2006-01-23 (+97d) | 1d → 1.5d |  |  | resources Writer 1; Editor 1; Project Manager 1 → Writer 2; Editor 2; baseline start 2005-10-18 → 2006-01-20; baseline finish 2005-10-18 → 2006-01-23 |
| 23 | Print final | 2005-10-19 → 2006-01-24 (+97d) | 2005-10-19 → 2006-01-24 (+97d) |  |  |  | resources Printer 1; Glossy paper → Printer 2; Subject Matter Expert 2; baseline start 2005-10-19 → 2006-01-24; baseline finish 2005-10-19 → 2006-01-24 |
| 24 | Book Complete | 2005-10-19 → 2006-01-24 (+97d) | 2005-10-19 → 2006-01-24 (+97d) |  |  |  | resources Project Manager 1; Writer 1 → Writer 2; baseline start 2005-10-19 → 2006-01-24; baseline finish 2005-10-19 → 2006-01-24 |

## Version 14 (saved 2003-11-05, file XML Training Manual.mpp)

Last finish 2006-01-24 → 2006-01-18 (-6d).

Changed:

| ID | Task | Start | Finish | Duration | Total float | Other |
| --- | --- | --- | --- | --- | --- | --- |
| 1 | Start Book |  |  |  | 57.5d → 52.75d | resources Writer 2 → none |
| 2 | **Research Phase** |  | 2005-11-09 → 2005-11-08 (-1d) | 7.5d → 7d | 4d → 1d | baseline finish 2005-11-09 → 2005-11-08 |
| 3 | Interview Subject Matter Expert |  | 2005-11-01 → 2005-10-31 (-1d) | 1.5d → 1d | 4d → 1d | resources Writer 2; Publisher 2 → none; baseline finish 2005-11-01 → 2005-10-31 |
| 4 | Investigate XML |  | 2005-11-07 → 2005-11-04 (-3d) |  | 4d → 1d | was named Investigate the software; resources Writer 2 → none; baseline finish 2005-11-07 → 2005-11-04 |
| 5 | Search the Web |  | 2005-11-09 → 2005-11-08 (-1d) |  | 4d → 1d | resources Writer 2; Project Manager 2 → none; baseline finish 2005-11-09 → 2005-11-08 |
| 6 | **Outline Phase** |  | 2005-11-29 → 2005-11-23 (-6d) | 12.5d → 10.75d | 0.5d → 0d | baseline finish 2005-11-29 → 2005-11-23 |
| 7 | Create outline |  | 2005-11-14 → 2005-11-11 (-3d) |  | 4d → 1d | resources Writer 2 → none; baseline finish 2005-11-14 → 2005-11-11 |
| 8 | Present to publisher |  | 2005-11-15 → 2005-11-14 (-1d) |  | 4d → 1d | resources Writer 2; Account Rep 2 → none; baseline finish 2005-11-15 → 2005-11-14 |
| 9 | Review with Subject Matter Expert | 2005-11-18 → 2005-11-15 (-3d) | 2005-11-22 → 2005-11-17 (-5d) | 2.25d → 3d | 0.5d → 0d | constraint start no earlier than 2005-11-18 → start no earlier than 2005-11-15; resources Writer 2; Publisher 2 → none; baseline start 2005-11-18 → 2005-11-15; baseline finish 2005-11-22 → 2005-11-17 |
| 10 | Revise outline | 2005-11-22 → 2005-11-18 (-4d) | 2005-11-29 → 2005-11-23 (-6d) |  | 0.5d → 0d | resources Writer 2 → none; baseline start 2005-11-22 → 2005-11-18; baseline finish 2005-11-29 → 2005-11-23 |
| 11 | **Development Phase** | 2005-11-30 → 2005-11-23 (-7d) | 2006-01-10 → 2006-01-06 (-4d) |  | 0.5d → 0d | baseline start 2005-11-30 → 2005-11-23; baseline finish 2006-01-10 → 2006-01-06 |
| 12 | Write content | 2005-11-30 → 2005-11-23 (-7d) | 2006-01-03 → 2005-12-30 (-4d) | 22d → 26.5d | 0.5d → 0d | resources Writer 2 → none; baseline start 2005-11-30 → 2005-11-23; baseline finish 2006-01-03 → 2005-12-30 |
| 13 | Add graphics | 2006-01-03 → 2005-12-30 (-4d) | 2006-01-10 → 2006-01-06 (-4d) |  | 0.5d → 0d | resources Artist 2; Project Manager 2 → none; baseline start 2006-01-03 → 2005-12-30; baseline finish 2006-01-10 → 2006-01-06 |
| 14 | **Edit Phase** | 2006-01-10 → 2006-01-06 (-4d) | 2006-01-17 → 2006-01-11 (-6d) | 5d → 3d |  | baseline start 2006-01-10 → 2006-01-06; baseline finish 2006-01-17 → 2006-01-11 |
| 15 | Check grammar, spelling, and proofread | 2006-01-10 → 2006-01-06 (-4d) | 2006-01-13 → 2006-01-11 (-2d) |  | 0.5d → 0d | resources Editor 2 → none; baseline start 2006-01-10 → 2006-01-06; baseline finish 2006-01-13 → 2006-01-11 |
| 16 | Check for technical accuracy | 2006-01-13 → 2006-01-09 (-4d) | 2006-01-17 → 2006-01-11 (-6d) |  |  | resources Editor 2; Publisher 2 → none; baseline start 2006-01-13 → 2006-01-09; baseline finish 2006-01-17 → 2006-01-11 |
| 17 | **Review Phase** | 2006-01-17 → 2006-01-11 (-6d) | 2006-01-19 → 2006-01-13 (-6d) |  |  | baseline start 2006-01-17 → 2006-01-11; baseline finish 2006-01-19 → 2006-01-13 |
| 18 | Approve editing changes | 2006-01-17 → 2006-01-11 (-6d) | 2006-01-18 → 2006-01-12 (-6d) |  |  | resources Writer 2 → none; baseline start 2006-01-17 → 2006-01-11; baseline finish 2006-01-18 → 2006-01-12 |
| 19 | Meet with editor | 2006-01-18 → 2006-01-12 (-6d) | 2006-01-19 → 2006-01-13 (-6d) |  |  | resources Writer 2; Editor 2 → none; baseline start 2006-01-18 → 2006-01-12; baseline finish 2006-01-19 → 2006-01-13 |
| 20 | **Print Phase** | 2006-01-19 → 2006-01-13 (-6d) | 2006-01-24 → 2006-01-18 (-6d) | 3.5d → 3d |  | baseline start 2006-01-19 → 2006-01-13; baseline finish 2006-01-24 → 2006-01-18 |
| 21 | Print proof | 2006-01-19 → 2006-01-13 (-6d) | 2006-01-20 → 2006-01-16 (-4d) |  |  | resources Printer 2; Plain paper → none; baseline start 2006-01-19 → 2006-01-13; baseline finish 2006-01-20 → 2006-01-16 |
| 22 | Review proof | 2006-01-20 → 2006-01-16 (-4d) | 2006-01-23 → 2006-01-17 (-6d) | 1.5d → 1d |  | resources Writer 2; Editor 2 → none; baseline start 2006-01-20 → 2006-01-16; baseline finish 2006-01-23 → 2006-01-17 |
| 23 | Print final | 2006-01-24 → 2006-01-17 (-7d) | 2006-01-24 → 2006-01-18 (-6d) |  |  | resources Printer 2; Subject Matter Expert 2 → none; baseline start 2006-01-24 → 2006-01-17; baseline finish 2006-01-24 → 2006-01-18 |
| 24 | Book Complete | 2006-01-24 → 2006-01-18 (-6d) | 2006-01-24 → 2006-01-18 (-6d) |  |  | resources Writer 2 → none; baseline start 2006-01-24 → 2006-01-18; baseline finish 2006-01-24 → 2006-01-18 |

## Version 15 (saved 2003-11-06, file Subproject HTML.mpp)

Last finish 2006-01-18 → 2006-01-20 (+2d).

Changed:

| ID | Task | Start | Finish | Duration | Total float | Other |
| --- | --- | --- | --- | --- | --- | --- |
| 1 | Start Book |  |  |  | 52.75d → 55.5d | resources none → Writer 3 |
| 2 | **Research Phase** |  | 2005-11-08 → 2005-11-09 (+1d) | 7d → 7.5d | 1d → 1.5d | baseline finish 2005-11-08 → 2005-11-09 |
| 3 | Interview Subject Matter Expert |  | 2005-10-31 → 2005-11-01 (+1d) | 1d → 1.5d | 1d → 1.5d | resources none → Writer 3; Publisher 3; baseline finish 2005-10-31 → 2005-11-01 |
| 4 | Investigate the software |  | 2005-11-04 → 2005-11-07 (+3d) |  | 1d → 1.5d | was named Investigate XML; resources none → Writer 3; baseline finish 2005-11-04 → 2005-11-07 |
| 5 | Search the Web |  | 2005-11-08 → 2005-11-09 (+1d) |  | 1d → 1.5d | resources none → Writer 3; Project Manager 3; baseline finish 2005-11-08 → 2005-11-09 |
| 6 | **Outline Phase** |  |  | 10.75d → 10.5d |  |  |
| 7 | Create outline |  | 2005-11-11 → 2005-11-14 (+3d) |  | 1d → 1.5d | resources none → Writer 3; baseline finish 2005-11-11 → 2005-11-14 |
| 8 | Present to publisher |  | 2005-11-14 → 2005-11-15 (+1d) |  | 1d → 1.5d | resources none → Writer 3; Account Rep 3; baseline finish 2005-11-14 → 2005-11-15 |
| 9 | Review with Subject Matter Expert | 2005-11-15 → 2005-11-16 (+1d) | 2005-11-17 → 2005-11-18 (+1d) | 3d → 2.25d |  | constraint start no earlier than 2005-11-15 → start no earlier than 2005-11-16; resources none → Writer 3; Publisher 3; baseline start 2005-11-15 → 2005-11-16; baseline finish 2005-11-17 → 2005-11-18 |
| 10 | Revise outline |  |  |  |  | resources none → Writer 3 |
| 11 | **Development Phase** | 2005-11-23 → 2005-11-28 (+5d) |  |  |  | baseline start 2005-11-23 → 2005-11-28 |
| 12 | Write content | 2005-11-23 → 2005-11-28 (+5d) |  | 26.5d → 22d |  | resources none → Writer 3; baseline start 2005-11-23 → 2005-11-28 |
| 13 | Add graphics |  |  |  |  | resources none → Artist 3; Project Manager 3 |
| 14 | **Edit Phase** |  | 2006-01-11 → 2006-01-13 (+2d) | 3d → 5d |  | baseline finish 2006-01-11 → 2006-01-13 |
| 15 | Check grammar, spelling, and proofread |  |  |  |  | resources none → Editor 3 |
| 16 | Check for technical accuracy | 2006-01-09 → 2006-01-11 (+2d) | 2006-01-11 → 2006-01-13 (+2d) |  |  | resources none → Editor 3; Publisher 3; baseline start 2006-01-09 → 2006-01-11; baseline finish 2006-01-11 → 2006-01-13 |
| 17 | **Review Phase** | 2006-01-11 → 2006-01-13 (+2d) | 2006-01-13 → 2006-01-17 (+4d) |  |  | baseline start 2006-01-11 → 2006-01-13; baseline finish 2006-01-13 → 2006-01-17 |
| 18 | Approve editing changes | 2006-01-11 → 2006-01-13 (+2d) | 2006-01-12 → 2006-01-16 (+4d) |  |  | resources none → Writer 3; baseline start 2006-01-11 → 2006-01-13; baseline finish 2006-01-12 → 2006-01-16 |
| 19 | Meet with editor | 2006-01-12 → 2006-01-16 (+4d) | 2006-01-13 → 2006-01-17 (+4d) |  |  | resources none → Writer 3; Editor 3; baseline start 2006-01-12 → 2006-01-16; baseline finish 2006-01-13 → 2006-01-17 |
| 20 | **Print Phase** | 2006-01-13 → 2006-01-17 (+4d) | 2006-01-18 → 2006-01-20 (+2d) | 3d → 3.5d |  | baseline start 2006-01-13 → 2006-01-17; baseline finish 2006-01-18 → 2006-01-20 |
| 21 | Print proof | 2006-01-13 → 2006-01-17 (+4d) | 2006-01-16 → 2006-01-18 (+2d) |  |  | resources none → Printer 3; Plain paper; baseline start 2006-01-13 → 2006-01-17; baseline finish 2006-01-16 → 2006-01-18 |
| 22 | Review proof | 2006-01-16 → 2006-01-18 (+2d) | 2006-01-17 → 2006-01-19 (+2d) | 1d → 1.5d |  | resources none → Writer 3; Editor 3; baseline start 2006-01-16 → 2006-01-18; baseline finish 2006-01-17 → 2006-01-19 |
| 23 | Print final | 2006-01-17 → 2006-01-20 (+3d) | 2006-01-18 → 2006-01-20 (+2d) |  |  | resources none → Printer 3; Glossy paper; baseline start 2006-01-17 → 2006-01-20; baseline finish 2006-01-18 → 2006-01-20 |
| 24 | Book Complete | 2006-01-18 → 2006-01-20 (+2d) | 2006-01-18 → 2006-01-20 (+2d) |  |  | resources none → Writer 3; baseline start 2006-01-18 → 2006-01-20; baseline finish 2006-01-18 → 2006-01-20 |

## Version 16 (saved 2003-11-06, file Subproject CSS.mpp)

Last finish 2006-01-20 → 2005-10-19 (-93d). Complete tasks 0 → 14.

Changed:

| ID | Task | Start | Finish | Duration | Complete | Total float | Other |
| --- | --- | --- | --- | --- | --- | --- | --- |
| 1 | Start Book | 2005-10-31 → 2005-08-01 A (-91d) | 2005-10-31 → 2005-08-01 A (-91d) |  | 0% → 100% | 55.5d → none | resources Writer 3 → Project Manager 1; Writer 1; baseline start 2005-10-31 → 2005-08-01; baseline finish 2005-10-31 → 2005-08-01 |
| 2 | **Research Phase** | 2005-10-31 → 2005-08-01 A (-91d) | 2005-11-09 → 2005-08-10 A (-91d) | 7.5d → 8d | 0% → 100% | 1.5d → none | baseline start 2005-10-31 → 2005-08-01; baseline finish 2005-11-09 → 2005-08-10 |
| 3 | Interview Subject Matter Expert | 2005-10-31 → 2005-08-01 A (-91d) | 2005-11-01 → 2005-08-01 A (-92d) | 1.5d → 1d | 0% → 100% | 1.5d → none | resources Writer 3; Publisher 3 → Project Manager 1; Writer 1; Subject Matter Expert 1; baseline start 2005-10-31 → 2005-08-01; baseline finish 2005-11-01 → 2005-08-02 |
| 4 | Investigate the software | 2005-11-01 → 2005-08-02 A (-91d) | 2005-11-07 → 2005-08-05 A (-94d) |  | 0% → 100% | 1.5d → none | resources Writer 3 → Writer 1; baseline start 2005-11-01 → 2005-08-03; baseline finish 2005-11-07 → 2005-08-08 |
| 5 | Search the Web | 2005-11-07 → 2005-08-08 A (-91d) | 2005-11-09 → 2005-08-10 A (-91d) |  | 0% → 100% | 1.5d → none | resources Writer 3; Project Manager 3 → Writer 1; Staff Assistant 1; baseline start 2005-11-07 → 2005-08-09; baseline finish 2005-11-09 → 2005-08-10 |
| 6 | **Outline Phase** | 2005-11-09 → 2005-08-11 A (-90d) | 2005-11-23 → 2005-08-26 A (-89d) | 10.5d → 12d | 0% → 100% | 0d → none | baseline start 2005-11-09 → 2005-08-11; baseline finish 2005-11-23 → 2005-08-23 |
| 7 | Create outline | 2005-11-09 → 2005-08-11 A (-90d) | 2005-11-14 → 2005-08-17 A (-89d) |  | 0% → 100% | 1.5d → none | resources Writer 3 → Writer 1; baseline start 2005-11-09 → 2005-08-11; baseline finish 2005-11-14 → 2005-08-15 |
| 8 | Present to publisher | 2005-11-14 → 2005-08-18 A (-88d) | 2005-11-15 → 2005-08-19 A (-88d) |  | 0% → 100% | 1.5d → none | resources Writer 3; Account Rep 3 → Writer 1; Project Manager 1; Publisher 1; baseline start 2005-11-14 → 2005-08-16; baseline finish 2005-11-15 → 2005-08-16 |
| 9 | Review with Subject Matter Expert | 2005-11-16 → 2005-08-19 A (-89d) | 2005-11-18 → 2005-08-23 A (-87d) |  | 0% → 100% | 0d → none | constraint start no earlier than 2005-11-16 → start no earlier than 2005-08-19; resources Writer 3; Publisher 3 → Writer 1; Subject Matter Expert 1; baseline start 2005-11-16 → 2005-08-19; baseline finish 2005-11-18 → 2005-08-22 |
| 10 | Revise outline | 2005-11-18 → 2005-08-23 A (-87d) | 2005-11-23 → 2005-08-26 A (-89d) |  | 0% → 100% | 0d → none | resources Writer 3 → Writer 1; baseline start 2005-11-18 → 2005-08-23; baseline finish 2005-11-23 → 2005-08-23 |
| 11 | **Development Phase** | 2005-11-28 → 2005-08-29 A (-91d) | 2006-01-06 → 2005-10-05 A (-93d) |  | 0% → 100% | 0d → none | baseline start 2005-11-28 → 2005-08-24; baseline finish 2006-01-06 → 2005-10-05 |
| 12 | Write content | 2005-11-28 → 2005-08-29 A (-91d) | 2005-12-30 → 2005-09-28 A (-93d) |  | 0% → 100% | 0d → none | resources Writer 3 → Writer 1; baseline start 2005-11-28 → 2005-08-24; baseline finish 2005-12-30 → 2005-09-28 |
| 13 | Add graphics | 2005-12-30 → 2005-09-29 A (-92d) | 2006-01-06 → 2005-10-05 A (-93d) |  | 0% → 100% | 0d → none | resources Artist 3; Project Manager 3 → Artist 1; Staff Assistant 1; baseline start 2005-12-30 → 2005-09-29; baseline finish 2006-01-06 → 2005-10-05 |
| 14 | **Edit Phase** | 2006-01-06 → 2005-10-06 A (-92d) | 2006-01-13 → 2005-10-12 A (-93d) |  | 0% → 100% | 0d → none | baseline start 2006-01-06 → 2005-10-06; baseline finish 2006-01-13 → 2005-10-12 |
| 15 | Check grammar, spelling, and proofread | 2006-01-06 → 2005-10-06 A (-92d) | 2006-01-11 → 2005-10-10 A (-93d) |  | 0% → 100% | 0d → none | resources Editor 3 → Editor 1; baseline start 2006-01-06 → 2005-10-06; baseline finish 2006-01-11 → 2005-10-10 |
| 16 | Check for technical accuracy | 2006-01-11 → 2005-10-11 A (-92d) | 2006-01-13 → 2005-10-12 A (-93d) |  | 0% → 100% | 0d → none | resources Editor 3; Publisher 3 → Editor 1; Subject Matter Expert 1; baseline start 2006-01-11 → 2005-10-11; baseline finish 2006-01-13 → 2005-10-12 |
| 17 | **Review Phase** | 2006-01-13 → 2005-10-13 A (-92d) | 2006-01-17 → 2005-10-14 A (-95d) |  | 0% → 100% | 0d → none | baseline start 2006-01-13 → 2005-10-13; baseline finish 2006-01-17 → 2005-10-14 |
| 18 | Approve editing changes | 2006-01-13 → 2005-10-13 A (-92d) | 2006-01-16 → 2005-10-13 A (-95d) |  | 0% → 100% | 0d → none | resources Writer 3 → Writer 1; baseline start 2006-01-13 → 2005-10-13; baseline finish 2006-01-16 → 2005-10-13 |
| 19 | Meet with editor | 2006-01-16 → 2005-10-14 A (-94d) | 2006-01-17 → 2005-10-14 A (-95d) |  | 0% → 100% | 0d → none | resources Writer 3; Editor 3 → Writer 1; Editor 1; baseline start 2006-01-16 → 2005-10-14; baseline finish 2006-01-17 → 2005-10-14 |
| 20 | **Print Phase** | 2006-01-17 → 2005-10-17 (-92d) | 2006-01-20 → 2005-10-19 (-93d) | 3.5d → 3d |  |  | baseline start 2006-01-17 → 2005-10-17; baseline finish 2006-01-20 → 2005-10-19 |
| 21 | Print proof | 2006-01-17 → 2005-10-17 (-92d) | 2006-01-18 → 2005-10-17 (-93d) |  |  |  | resources Printer 3; Plain paper → Printer 1; Plain paper; baseline start 2006-01-17 → 2005-10-17; baseline finish 2006-01-18 → 2005-10-17 |
| 22 | Review proof | 2006-01-18 → 2005-10-18 (-92d) | 2006-01-19 → 2005-10-18 (-93d) | 1.5d → 1d |  |  | resources Writer 3; Editor 3 → Writer 1; Editor 1; Project Manager 1; baseline start 2006-01-18 → 2005-10-18; baseline finish 2006-01-19 → 2005-10-18 |
| 23 | Print final | 2006-01-20 → 2005-10-19 (-93d) | 2006-01-20 → 2005-10-19 (-93d) |  |  |  | resources Printer 3; Glossy paper → Printer 1; Glossy paper; baseline start 2006-01-20 → 2005-10-19; baseline finish 2006-01-20 → 2005-10-19 |
| 24 | Book Complete | 2006-01-20 → 2005-10-19 (-93d) | 2006-01-20 → 2005-10-19 (-93d) |  |  |  | resources Writer 3 → Project Manager 1; Writer 1; baseline start 2006-01-20 → 2005-10-19; baseline finish 2006-01-20 → 2005-10-19 |

## Version 17 (saved 2003-11-06, file Subproject XML.mpp)

Last finish 2005-10-19 → 2006-01-26 (+99d). Complete tasks 14 → 0.

Added:

| ID | Task | Duration | Start | Finish | Predecessors | Resources |
| --- | --- | --- | --- | --- | --- | --- |
| 4 | Investigate XML | 4d | 2005-11-01 | 2005-11-04 | 3 | Writer 2 |

Removed: 4 Investigate the software

Changed:

| ID | Task | Start | Finish | Duration | Complete | Total float | Predecessors | Other |
| --- | --- | --- | --- | --- | --- | --- | --- | --- |
| 1 | Start Book | 2005-08-01 A → 2005-10-31 (+91d) | 2005-08-01 A → 2005-10-31 (+91d) |  | 100% → 0% | none → 59.25d |  | resources Project Manager 1; Writer 1 → Project Manager 2; Writer 2; baseline start 2005-08-01 → 2005-10-31; baseline finish 2005-08-01 → 2005-10-31 |
| 2 | **Research Phase** | 2005-08-01 A → 2005-10-31 (+91d) | 2005-08-10 A → 2005-11-08 (+90d) | 8d → 7d | 100% → 0% | none → 1d |  | baseline start 2005-08-01 → 2005-10-31; baseline finish 2005-08-10 → 2005-11-08 |
| 3 | Interview Subject Matter Expert | 2005-08-01 A → 2005-10-31 (+91d) | 2005-08-01 A → 2005-10-31 (+91d) |  | 100% → 0% | none → 1d |  | resources Project Manager 1; Writer 1; Subject Matter Expert 1 → Project Manager 2; Writer 2; Subject Matter Expert 2; baseline start 2005-08-01 → 2005-10-31; baseline finish 2005-08-02 → 2005-10-31 |
| 5 | Search the Web | 2005-08-08 A → 2005-11-07 (+91d) | 2005-08-10 A → 2005-11-08 (+90d) |  | 100% → 0% | none → 1d | Investigate the software → 4 | resources Writer 1; Staff Assistant 1 → Writer 2; Staff Assistant 2; baseline start 2005-08-09 → 2005-11-07; baseline finish 2005-08-10 → 2005-11-08 |
| 6 | **Outline Phase** | 2005-08-11 A → 2005-11-09 (+90d) | 2005-08-26 A → 2005-11-23 (+89d) | 12d → 10.75d | 100% → 0% | none → 0d |  | baseline start 2005-08-11 → 2005-11-09; baseline finish 2005-08-23 → 2005-11-23 |
| 7 | Create outline | 2005-08-11 A → 2005-11-09 (+90d) | 2005-08-17 A → 2005-11-11 (+86d) |  | 100% → 0% | none → 1d |  | resources Writer 1 → Writer 2; baseline start 2005-08-11 → 2005-11-09; baseline finish 2005-08-15 → 2005-11-11 |
| 8 | Present to publisher | 2005-08-18 A → 2005-11-14 (+88d) | 2005-08-19 A → 2005-11-14 (+87d) |  | 100% → 0% | none → 1d |  | resources Writer 1; Project Manager 1; Publisher 1 → Writer 2; Project Manager 2; Publisher 2; baseline start 2005-08-16 → 2005-11-14; baseline finish 2005-08-16 → 2005-11-14 |
| 9 | Review with Subject Matter Expert | 2005-08-19 A → 2005-11-15 (+88d) | 2005-08-23 A → 2005-11-17 (+86d) | 2.25d → 3d | 100% → 0% | none → 0d |  | constraint start no earlier than 2005-08-19 → start no earlier than 2005-11-15; resources Writer 1; Subject Matter Expert 1 → Writer 2; Subject Matter Expert 2; baseline start 2005-08-19 → 2005-11-15; baseline finish 2005-08-22 → 2005-11-17 |
| 10 | Revise outline | 2005-08-23 A → 2005-11-18 (+87d) | 2005-08-26 A → 2005-11-23 (+89d) |  | 100% → 0% | none → 0d |  | resources Writer 1 → Writer 2; baseline start 2005-08-23 → 2005-11-18; baseline finish 2005-08-23 → 2005-11-23 |
| 11 | **Development Phase** | 2005-08-29 A → 2005-11-23 (+86d) | 2005-10-05 A → 2006-01-12 (+99d) | 27d → 31.5d | 100% → 0% | none → 0d |  | baseline start 2005-08-24 → 2005-11-23; baseline finish 2005-10-05 → 2006-01-06 |
| 12 | Write content | 2005-08-29 A → 2005-11-23 (+86d) | 2005-09-28 A → 2006-01-05 (+99d) | 22d → 26.5d | 100% → 0% | none → 0d |  | resources Writer 1 → Writer 2; baseline start 2005-08-24 → 2005-11-23; baseline finish 2005-09-28 → 2005-12-30 |
| 13 | Add graphics | 2005-09-29 A → 2006-01-05 (+98d) | 2005-10-05 A → 2006-01-12 (+99d) |  | 100% → 0% | none → 0d |  | resources Artist 1; Staff Assistant 1 → Artist 2; Staff Assistant 2; baseline start 2005-09-29 → 2005-12-30; baseline finish 2005-10-05 → 2006-01-06 |
| 14 | **Edit Phase** | 2005-10-06 A → 2006-01-12 (+98d) | 2005-10-12 A → 2006-01-19 (+99d) |  | 100% → 0% | none → 0d |  | baseline start 2005-10-06 → 2006-01-06; baseline finish 2005-10-12 → 2006-01-13 |
| 15 | Check grammar, spelling, and proofread | 2005-10-06 A → 2006-01-12 (+98d) | 2005-10-10 A → 2006-01-17 (+99d) |  | 100% → 0% | none → 0d |  | resources Editor 1 → Editor 2; baseline start 2005-10-06 → 2006-01-06; baseline finish 2005-10-10 → 2006-01-11 |
| 16 | Check for technical accuracy | 2005-10-11 A → 2006-01-17 (+98d) | 2005-10-12 A → 2006-01-19 (+99d) |  | 100% → 0% | none → 0d |  | resources Editor 1; Subject Matter Expert 1 → Editor 2; Subject Matter Expert 2; baseline start 2005-10-11 → 2006-01-11; baseline finish 2005-10-12 → 2006-01-13 |
| 17 | **Review Phase** | 2005-10-13 A → 2006-01-19 (+98d) | 2005-10-14 A → 2006-01-23 (+101d) |  | 100% → 0% | none → 0d |  | baseline start 2005-10-13 → 2006-01-13; baseline finish 2005-10-14 → 2006-01-17 |
| 18 | Approve editing changes | 2005-10-13 A → 2006-01-19 (+98d) | 2005-10-13 A → 2006-01-20 (+99d) |  | 100% → 0% | none → 0d |  | resources Writer 1 → Writer 2; baseline start 2005-10-13 → 2006-01-13; baseline finish 2005-10-13 → 2006-01-16 |
| 19 | Meet with editor | 2005-10-14 A → 2006-01-20 (+98d) | 2005-10-14 A → 2006-01-23 (+101d) |  | 100% → 0% | none → 0d |  | resources Writer 1; Editor 1 → Writer 2; Editor 2; baseline start 2005-10-14 → 2006-01-16; baseline finish 2005-10-14 → 2006-01-17 |
| 20 | **Print Phase** | 2005-10-17 → 2006-01-23 (+98d) | 2005-10-19 → 2006-01-26 (+99d) |  |  |  |  | baseline start 2005-10-17 → 2006-01-17; baseline finish 2005-10-19 → 2006-01-20 |
| 21 | Print proof | 2005-10-17 → 2006-01-23 (+98d) | 2005-10-17 → 2006-01-24 (+99d) |  |  |  |  | resources Printer 1; Plain paper → Printer 2; Plain paper; baseline start 2005-10-17 → 2006-01-17; baseline finish 2005-10-17 → 2006-01-18 |
| 22 | Review proof | 2005-10-18 → 2006-01-24 (+98d) | 2005-10-18 → 2006-01-25 (+99d) |  |  |  |  | resources Writer 1; Editor 1; Project Manager 1 → Writer 2; Editor 2; Project Manager 2; baseline start 2005-10-18 → 2006-01-18; baseline finish 2005-10-18 → 2006-01-19 |
| 23 | Print final | 2005-10-19 → 2006-01-25 (+98d) | 2005-10-19 → 2006-01-26 (+99d) |  |  |  |  | resources Printer 1; Glossy paper → Printer 2; Glossy paper; baseline start 2005-10-19 → 2006-01-19; baseline finish 2005-10-19 → 2006-01-20 |
| 24 | Book Complete | 2005-10-19 → 2006-01-26 (+99d) | 2005-10-19 → 2006-01-26 (+99d) |  |  |  |  | resources Project Manager 1; Writer 1 → Project Manager 2; Writer 2; baseline start 2005-10-19 → 2006-01-20; baseline finish 2005-10-19 → 2006-01-20 |

## Version 18 (saved 2003-11-06, file Subproject Unix.mpp)

Last finish 2006-01-26 → 2006-01-25 (-1d).

Added:

| ID | Task | Duration | Start | Finish | Predecessors | Resources |
| --- | --- | --- | --- | --- | --- | --- |
| 4 | Investigate Unix | 4d | 2005-11-02 | 2005-11-07 | 3 | Writer 4 |

Removed: 4 Investigate XML

Changed:

| ID | Task | Start | Finish | Duration | Total float | Predecessors | Other |
| --- | --- | --- | --- | --- | --- | --- | --- |
| 1 | Start Book |  |  |  | 59.25d → 57.75d |  | resources Project Manager 2; Writer 2 → Project Manager 4; Writer 4 |
| 3 | Interview Subject Matter Expert |  | 2005-10-31 → 2005-11-01 (+1d) | 1d → 2d | 1d → 4d |  | resources Project Manager 2; Writer 2; Subject Matter Expert 2 → Project Manager 4; Writer 4; Subject Matter Expert 4; baseline finish 2005-10-31 → 2005-11-01 |
| 5 | Search the Web | 2005-11-07 → 2005-11-08 (+1d) |  | 2d → 1d | 1d → 4d | Investigate XML → 4 | resources Writer 2; Staff Assistant 2 → Writer 4; Staff Assistant 4; baseline start 2005-11-07 → 2005-11-08 |
| 6 | **Outline Phase** |  | 2005-11-23 → 2005-11-30 (+7d) | 10.75d → 13.75d |  |  | baseline finish 2005-11-23 → 2005-11-28 |
| 7 | Create outline |  |  |  | 1d → 4d |  | resources Writer 2 → Writer 4 |
| 8 | Present to publisher |  |  |  | 1d → 4d |  | resources Writer 2; Project Manager 2; Publisher 2 → Writer 4; Project Manager 4; Publisher 4 |
| 9 | Review with Subject Matter Expert | 2005-11-15 → 2005-11-18 (+3d) | 2005-11-17 → 2005-11-22 (+5d) |  |  |  | constraint start no earlier than 2005-11-15 → start no earlier than 2005-11-18; resources Writer 2; Subject Matter Expert 2 → Writer 4; Subject Matter Expert 4; baseline start 2005-11-15 → 2005-11-18; baseline finish 2005-11-17 → 2005-11-22 |
| 10 | Revise outline | 2005-11-18 → 2005-11-23 (+5d) | 2005-11-23 → 2005-11-30 (+7d) |  |  |  | resources Writer 2 → Writer 4; baseline start 2005-11-18 → 2005-11-23; baseline finish 2005-11-23 → 2005-11-28 |
| 11 | **Development Phase** | 2005-11-23 → 2005-11-30 (+7d) | 2006-01-12 → 2006-01-11 (-1d) | 31.5d → 27d |  |  | baseline start 2005-11-23 → 2005-11-28; baseline finish 2006-01-06 → 2006-01-04 |
| 12 | Write content | 2005-11-23 → 2005-11-30 (+7d) | 2006-01-05 → 2006-01-04 (-1d) | 26.5d → 22d |  |  | resources Writer 2 → Writer 4; baseline start 2005-11-23 → 2005-11-28; baseline finish 2005-12-30 → 2005-12-28 |
| 13 | Add graphics | 2006-01-05 → 2006-01-04 (-1d) | 2006-01-12 → 2006-01-11 (-1d) |  |  |  | resources Artist 2; Staff Assistant 2 → Artist 4; Staff Assistant 4; baseline start 2005-12-30 → 2005-12-28; baseline finish 2006-01-06 → 2006-01-04 |
| 14 | **Edit Phase** | 2006-01-12 → 2006-01-11 (-1d) | 2006-01-19 → 2006-01-18 (-1d) |  |  |  | baseline start 2006-01-06 → 2006-01-04; baseline finish 2006-01-13 → 2006-01-11 |
| 15 | Check grammar, spelling, and proofread | 2006-01-12 → 2006-01-11 (-1d) | 2006-01-17 → 2006-01-16 (-1d) |  |  |  | resources Editor 2 → Editor 4; baseline start 2006-01-06 → 2006-01-04; baseline finish 2006-01-11 → 2006-01-09 |
| 16 | Check for technical accuracy | 2006-01-17 → 2006-01-16 (-1d) | 2006-01-19 → 2006-01-18 (-1d) |  |  |  | resources Editor 2; Subject Matter Expert 2 → Editor 4; Subject Matter Expert 4; baseline start 2006-01-11 → 2006-01-09; baseline finish 2006-01-13 → 2006-01-11 |
| 17 | **Review Phase** | 2006-01-19 → 2006-01-18 (-1d) | 2006-01-23 → 2006-01-20 (-3d) |  |  |  | baseline start 2006-01-13 → 2006-01-11; baseline finish 2006-01-17 → 2006-01-13 |
| 18 | Approve editing changes | 2006-01-19 → 2006-01-18 (-1d) | 2006-01-20 → 2006-01-19 (-1d) |  |  |  | resources Writer 2 → Writer 4; baseline start 2006-01-13 → 2006-01-11; baseline finish 2006-01-16 → 2006-01-12 |
| 19 | Meet with editor | 2006-01-20 → 2006-01-19 (-1d) | 2006-01-23 → 2006-01-20 (-3d) |  |  |  | resources Writer 2; Editor 2 → Writer 4; Editor 4; baseline start 2006-01-16 → 2006-01-12; baseline finish 2006-01-17 → 2006-01-13 |
| 20 | **Print Phase** | 2006-01-23 → 2006-01-20 (-3d) | 2006-01-26 → 2006-01-25 (-1d) |  |  |  | baseline start 2006-01-17 → 2006-01-13; baseline finish 2006-01-20 → 2006-01-18 |
| 21 | Print proof | 2006-01-23 → 2006-01-20 (-3d) | 2006-01-24 → 2006-01-23 (-1d) |  |  |  | resources Printer 2; Plain paper → Printer 4; Plain paper; baseline start 2006-01-17 → 2006-01-13; baseline finish 2006-01-18 → 2006-01-16 |
| 22 | Review proof | 2006-01-24 → 2006-01-23 (-1d) | 2006-01-25 → 2006-01-24 (-1d) |  |  |  | resources Writer 2; Editor 2; Project Manager 2 → Writer 4; Editor 4; Project Manager 4; baseline start 2006-01-18 → 2006-01-16; baseline finish 2006-01-19 → 2006-01-17 |
| 23 | Print final | 2006-01-25 → 2006-01-24 (-1d) | 2006-01-26 → 2006-01-25 (-1d) |  |  |  | resources Printer 2; Glossy paper → Printer 4; Glossy paper; baseline start 2006-01-19 → 2006-01-17; baseline finish 2006-01-20 → 2006-01-18 |
| 24 | Book Complete | 2006-01-26 → 2006-01-25 (-1d) | 2006-01-26 → 2006-01-25 (-1d) |  |  |  | resources Project Manager 2; Writer 2 → Project Manager 4; Writer 4; baseline start 2006-01-20 → 2006-01-18; baseline finish 2006-01-20 → 2006-01-18 |

## Version 19 (saved 2003-11-06, file CSS Book.mpp)

Last finish 2006-01-25 → 2005-09-28 (-119d).

Added:

| ID | Task | Duration | Start | Finish | Predecessors | Resources |
| --- | --- | --- | --- | --- | --- | --- |
| 8 | Revise Outline | 1d | 2005-08-12 | 2005-08-15 | 7 | Staff Assistant 1 |
| 10 | Outline complete | 0d | 2005-08-16 | 2005-08-16 | 9 |  |
| 14 | Development complete | 0d | 2005-09-13 | 2005-09-13 | 13 |  |

Removed: 3 Interview Subject Matter Expert; 4 Investigate Unix

Changed:

| ID | Task | Start | Finish | Duration | Total float | Predecessors | Other |
| --- | --- | --- | --- | --- | --- | --- | --- |
| 1 | Start Book | 2005-10-31 → 2005-08-01 (-91d) | 2005-10-31 → 2005-08-01 (-91d) |  | 57.75d → 0d |  | resources Project Manager 4; Writer 4 → none; baseline start 2005-10-31 → 2005-08-01; baseline finish 2005-10-31 → 2005-08-01 |
| 2 | **Research Phase** | 2005-10-31 → 2005-08-01 (-91d) | 2005-11-08 → 2005-08-05 (-95d) | 7d → 4.12d | 4d → 0d |  | baseline start 2005-10-31 → 2005-08-01; baseline finish 2005-11-08 → 2005-08-05 |
| 3 | Interview Subject Matter Experts | 2005-11-23 → 2005-08-01 (-114d) | 2005-11-30 → 2005-08-02 (-120d) | 3.75d → 2d |  | 9 → 1 | was named Revise outline; resources Writer 4 → Writer 1; baseline start 2005-11-23 → 2005-08-01; baseline finish 2005-11-28 → 2005-08-04 |
| 4 | Search the Web | 2005-11-08 → 2005-08-01 (-99d) | 2005-11-08 → 2005-08-05 (-95d) | 1d → 3.25d | 4d → 0d | Investigate Unix → 3SS+2% | resources Writer 4; Staff Assistant 4 → Staff Assistant 1; Staff Assistant 2; Writer 1; baseline start 2005-11-08 → 2005-08-01; baseline finish 2005-11-08 → 2005-08-05 |
| 5 | **Outline Phase** | 2005-11-09 → 2005-08-05 (-96d) | 2005-11-30 → 2005-08-16 (-106d) | 13.75d → 7d |  |  | baseline start 2005-11-09 → 2005-08-05; baseline finish 2005-11-28 → 2005-08-16 |
| 6 | Create outline | 2005-11-09 → 2005-08-05 (-96d) | 2005-11-11 → 2005-08-12 (-91d) | 3d → 5d | 4d → 0d |  | resources Writer 4 → Writer 1; baseline start 2005-11-09 → 2005-08-05; baseline finish 2005-11-11 → 2005-08-12 |
| 7 | Present to publisher | 2005-11-14 → 2005-08-12 (-94d) | 2005-11-14 → 2005-08-12 (-94d) | 1d → 0.5d | 4d → 0d |  | resources Writer 4; Project Manager 4; Publisher 4 → Writer 1; Publisher 1; baseline start 2005-11-14 → 2005-08-12; baseline finish 2005-11-14 → 2005-08-12 |
| 9 | Review with Subject Matter Expert | 2005-11-18 → 2005-08-15 (-95d) | 2005-11-22 → 2005-08-16 (-98d) | 3d → 0.5d | 0d → 18.5d | 7SS → 8 | constraint start no earlier than 2005-11-18 → none; resources Writer 4; Subject Matter Expert 4 → Subject Matter Expert 1; Subject Matter Expert 2; baseline start 2005-11-18 → 2005-08-15; baseline finish 2005-11-22 → 2005-08-16 |
| 11 | **Development Phase** | 2005-11-30 → 2005-08-15 (-107d) | 2006-01-11 → 2005-09-13 (-120d) | 27d → 20d |  |  | baseline start 2005-11-28 → 2005-08-15; baseline finish 2006-01-04 → 2005-09-13 |
| 12 | Write content | 2005-11-30 → 2005-08-15 (-107d) | 2006-01-04 → 2005-09-12 (-114d) | 22d → 20d |  | 3 → 10FF, 8 | resources Writer 4 → Writer 1; baseline start 2005-11-28 → 2005-08-15; baseline finish 2005-12-28 → 2005-09-12 |
| 13 | Add graphics | 2006-01-04 → 2005-09-06 (-120d) | 2006-01-11 → 2005-09-13 (-120d) | 5d → 1w |  | 12 → 12FF+1d | resources Artist 4; Staff Assistant 4 → Artist 1; baseline start 2005-12-28 → 2005-09-06; baseline finish 2006-01-04 → 2005-09-13 |
| 15 | **Edit Phase** | 2006-01-11 → 2005-09-13 (-120d) | 2006-01-18 → 2005-09-20 (-120d) |  |  |  | baseline start 2006-01-04 → 2005-09-13; baseline finish 2006-01-11 → 2005-09-20 |
| 16 | Check grammar, spelling, and proofread | 2006-01-11 → 2005-09-13 (-120d) | 2006-01-16 → 2005-09-20 (-118d) | 3d → 1w |  | 13 → 14 | constraint none → start no earlier than 2005-09-13; resources Editor 4 → Editor 1 [25%]; baseline start 2006-01-04 → 2005-09-13; baseline finish 2006-01-09 → 2005-09-20 |
| 17 | Check for technical accuracy | 2006-01-16 → 2005-09-13 (-125d) | 2006-01-18 → 2005-09-20 (-120d) | 2d → 1w |  |  | resources Editor 4; Subject Matter Expert 4 → Subject Matter Expert 1; Subject Matter Expert 2; baseline start 2006-01-09 → 2005-09-13; baseline finish 2006-01-11 → 2005-09-20 |
| 18 | **Review Phase** | 2006-01-18 → 2005-09-20 (-120d) | 2006-01-20 → 2005-09-21 (-121d) | 2d → 1.25d |  |  | baseline start 2006-01-11 → 2005-09-20; baseline finish 2006-01-13 → 2005-09-21 |
| 19 | Approve editing changes | 2006-01-18 → 2005-09-20 (-120d) | 2006-01-19 → 2005-09-21 (-120d) |  |  |  | resources Writer 4 → Writer 1; Staff Assistant 2; baseline start 2006-01-11 → 2005-09-20; baseline finish 2006-01-12 → 2005-09-21 |
| 20 | Meet with editor | 2006-01-19 → 2005-09-21 (-120d) | 2006-01-20 → 2005-09-21 (-121d) | 1d → 0.25d |  |  | resources Writer 4; Editor 4 → Writer 1; Editor 1; baseline start 2006-01-12 → 2005-09-21; baseline finish 2006-01-13 → 2005-09-21 |
| 21 | **Print Phase** | 2006-01-20 → 2005-09-21 (-121d) | 2006-01-25 → 2005-09-28 (-119d) | 3d → 5d |  |  | baseline start 2006-01-13 → 2005-09-21; baseline finish 2006-01-18 → 2005-09-28 |
| 22 | Print proof | 2006-01-20 → 2005-09-21 (-121d) | 2006-01-23 → 2005-09-22 (-123d) |  |  |  | resources Printer 4; Plain paper → Printer 1; baseline start 2006-01-13 → 2005-09-21; baseline finish 2006-01-16 → 2005-09-22 |
| 23 | Review proof | 2006-01-23 → 2005-09-22 (-123d) | 2006-01-24 → 2005-09-27 (-119d) | 1d → 3d |  |  | resources Writer 4; Editor 4; Project Manager 4 → Writer 1; Staff Assistant 1; baseline start 2006-01-16 → 2005-09-22; baseline finish 2006-01-17 → 2005-09-27 |
| 24 | Print final | 2006-01-24 → 2005-09-27 (-119d) | 2006-01-25 → 2005-09-28 (-119d) |  |  |  | resources Printer 4; Glossy paper → Printer 1; baseline start 2006-01-17 → 2005-09-27; baseline finish 2006-01-18 → 2005-09-28 |
| 25 | Book Complete | 2006-01-25 → 2005-09-28 (-119d) | 2006-01-25 → 2005-09-28 (-119d) |  | 0d → 0.12d |  | constraint none → finish no later than 2005-09-28; resources Project Manager 4; Writer 4 → none; baseline start 2006-01-18 → 2005-09-28; baseline finish 2006-01-18 → 2005-09-28 |

## Version 20 (saved 2003-11-06, file CSS Week 13.mpp)

Last finish 2005-09-28 → 2005-10-19 (+21d). Complete tasks 0 → 14.

Added:

| ID | Task | Duration | Start | Finish | Resources |
| --- | --- | --- | --- | --- | --- |
| 3 | Interview Subject Matter Expert | 1d | 2005-08-01 A | 2005-08-01 A | Project Manager 1; Writer 1; Subject Matter Expert 1 |

Removed: 8 Revise Outline; 14 Development complete

Changed:

| ID | Task | Start | Finish | Duration | Complete | Total float | Predecessors | Other |
| --- | --- | --- | --- | --- | --- | --- | --- | --- |
| 1 | Start Book | 2005-08-01 A | 2005-08-01 A |  | 0% → 100% | 0d → none |  | resources none → Project Manager 1; Writer 1 |
| 2 | **Research Phase** | 2005-08-01 A | 2005-08-05 → 2005-08-10 A (+5d) | 4.12d → 8d | 0% → 100% | 0d → none |  | baseline finish 2005-08-05 → 2005-08-10 |
| 4 | Investigate the software | 2005-08-01 → 2005-08-02 A (+1d) | 2005-08-02 → 2005-08-05 A (+3d) | 2d → 4d | 0% → 100% | 0d → none | 1 → 3 | was named Interview Subject Matter Experts; baseline start 2005-08-01 → 2005-08-03; baseline finish 2005-08-04 → 2005-08-08 |
| 5 | Search the Web | 2005-08-01 → 2005-08-08 A (+7d) | 2005-08-05 → 2005-08-10 A (+5d) | 3.25d → 2d | 0% → 100% | 0d → none | 4SS+2% → 4 | resources Staff Assistant 1; Staff Assistant 2; Writer 1 → Writer 1; Staff Assistant 1; baseline start 2005-08-01 → 2005-08-09; baseline finish 2005-08-05 → 2005-08-10 |
| 6 | **Outline Phase** | 2005-08-05 → 2005-08-11 A (+6d) | 2005-08-16 → 2005-08-26 A (+10d) | 7d → 12d | 0% → 100% | 0d → none |  | baseline start 2005-08-05 → 2005-08-11; baseline finish 2005-08-16 → 2005-08-23 |
| 7 | Create outline | 2005-08-05 → 2005-08-11 A (+6d) | 2005-08-12 → 2005-08-17 A (+5d) | 5d → 3d | 0% → 100% | 0d → none |  | baseline start 2005-08-05 → 2005-08-11; baseline finish 2005-08-12 → 2005-08-15 |
| 8 | Present to publisher | 2005-08-12 → 2005-08-18 A (+6d) | 2005-08-12 → 2005-08-19 A (+7d) | 0.5d → 1d | 0% → 100% | 0d → none |  | resources Writer 1; Publisher 1 → Writer 1; Project Manager 1; Publisher 1; baseline start 2005-08-12 → 2005-08-16; baseline finish 2005-08-12 → 2005-08-16 |
| 9 | Review with Subject Matter Expert | 2005-08-15 → 2005-08-19 A (+4d) | 2005-08-16 → 2005-08-23 A (+7d) | 0.5d → 2.25d | 0% → 100% | 18.5d → none | Revise Outline → 8SS | constraint none → start no earlier than 2005-08-19; resources Subject Matter Expert 1; Subject Matter Expert 2 → Writer 1; Subject Matter Expert 1; baseline start 2005-08-15 → 2005-08-19; baseline finish 2005-08-16 → 2005-08-22 |
| 10 | Revise outline | 2005-08-16 → 2005-08-23 A (+7d) | 2005-08-16 → 2005-08-26 A (+10d) | 0d → 3.75d | 0% → 100% | 18.5d → none |  | was named Outline complete; resources none → Writer 1; baseline start 2005-08-16 → 2005-08-23; baseline finish 2005-08-16 → 2005-08-23 |
| 11 | **Development Phase** | 2005-08-15 → 2005-08-29 A (+14d) | 2005-09-13 → 2005-10-05 A (+22d) | 20d → 27d | 0% → 100% | 0d → none |  | baseline start 2005-08-15 → 2005-08-24; baseline finish 2005-09-13 → 2005-10-05 |
| 12 | Write content | 2005-08-15 → 2005-08-29 A (+14d) | 2005-09-12 → 2005-09-28 A (+16d) | 20d → 22d | 0% → 100% | 0d → none | 10FF, Revise Outline → 10 | baseline start 2005-08-15 → 2005-08-24; baseline finish 2005-09-12 → 2005-09-28 |
| 13 | Add graphics | 2005-09-06 → 2005-09-29 A (+23d) | 2005-09-13 → 2005-10-05 A (+22d) | 1w → 5d | 0% → 100% | 0d → none | 12FF+1d → 12 | resources Artist 1 → Artist 1; Staff Assistant 1; baseline start 2005-09-06 → 2005-09-29; baseline finish 2005-09-13 → 2005-10-05 |
| 14 | **Edit Phase** | 2005-09-13 → 2005-10-06 A (+23d) | 2005-09-20 → 2005-10-12 A (+22d) |  | 0% → 100% | 0d → none |  | baseline start 2005-09-13 → 2005-10-06; baseline finish 2005-09-20 → 2005-10-12 |
| 15 | Check grammar, spelling, and proofread | 2005-09-13 → 2005-10-06 A (+23d) | 2005-09-20 → 2005-10-10 A (+20d) | 1w → 3d | 0% → 100% | 0d → none | Development complete → 13 | constraint start no earlier than 2005-09-13 → none; resources Editor 1 [25%] → Editor 1; baseline start 2005-09-13 → 2005-10-06; baseline finish 2005-09-20 → 2005-10-10 |
| 16 | Check for technical accuracy | 2005-09-13 → 2005-10-11 A (+28d) | 2005-09-20 → 2005-10-12 A (+22d) | 1w → 2d | 0% → 100% | 0d → none |  | resources Subject Matter Expert 1; Subject Matter Expert 2 → Editor 1; Subject Matter Expert 1; baseline start 2005-09-13 → 2005-10-11; baseline finish 2005-09-20 → 2005-10-12 |
| 17 | **Review Phase** | 2005-09-20 → 2005-10-13 A (+23d) | 2005-09-21 → 2005-10-14 A (+23d) | 1.25d → 2d | 0% → 100% | 0d → none |  | baseline start 2005-09-20 → 2005-10-13; baseline finish 2005-09-21 → 2005-10-14 |
| 18 | Approve editing changes | 2005-09-20 → 2005-10-13 A (+23d) | 2005-09-21 → 2005-10-13 A (+22d) |  | 0% → 100% | 0d → none |  | resources Writer 1; Staff Assistant 2 → Writer 1; baseline start 2005-09-20 → 2005-10-13; baseline finish 2005-09-21 → 2005-10-13 |
| 19 | Meet with editor | 2005-09-21 → 2005-10-14 A (+23d) | 2005-09-21 → 2005-10-14 A (+23d) | 0.25d → 1d | 0% → 100% | 0d → none |  | baseline start 2005-09-21 → 2005-10-14; baseline finish 2005-09-21 → 2005-10-14 |
| 20 | **Print Phase** | 2005-09-21 → 2005-10-17 (+26d) | 2005-09-28 → 2005-10-19 (+21d) | 5d → 3d |  |  |  | baseline start 2005-09-21 → 2005-10-17; baseline finish 2005-09-28 → 2005-10-19 |
| 21 | Print proof | 2005-09-21 → 2005-10-17 (+26d) | 2005-09-22 → 2005-10-17 (+25d) |  |  |  |  | resources Printer 1 → Printer 1; Plain paper; baseline start 2005-09-21 → 2005-10-17; baseline finish 2005-09-22 → 2005-10-17 |
| 22 | Review proof | 2005-09-22 → 2005-10-18 (+26d) | 2005-09-27 → 2005-10-18 (+21d) | 3d → 1d |  |  |  | resources Writer 1; Staff Assistant 1 → Writer 1; Editor 1; Project Manager 1; baseline start 2005-09-22 → 2005-10-18; baseline finish 2005-09-27 → 2005-10-18 |
| 23 | Print final | 2005-09-27 → 2005-10-19 (+22d) | 2005-09-28 → 2005-10-19 (+21d) |  |  |  |  | resources Printer 1 → Printer 1; Glossy paper; baseline start 2005-09-27 → 2005-10-19; baseline finish 2005-09-28 → 2005-10-19 |
| 24 | Book Complete | 2005-09-28 → 2005-10-19 (+21d) | 2005-09-28 → 2005-10-19 (+21d) |  |  | 0.12d → 0d |  | constraint finish no later than 2005-09-28 → none; resources none → Project Manager 1; Writer 1; baseline start 2005-09-28 → 2005-10-19; baseline finish 2005-09-28 → 2005-10-19 |

## Version 21 (saved 2003-11-06, file Unix Training Manual.mpp)

Last finish 2005-10-19 → 2006-01-18 (+91d). Complete tasks 14 → 0.

Changed:

| ID | Task | Start | Finish | Duration | Complete | Total float | Other |
| --- | --- | --- | --- | --- | --- | --- | --- |
| 1 | Start Book | 2005-08-01 A → 2005-10-31 (+91d) | 2005-08-01 A → 2005-10-31 (+91d) |  | 100% → 0% | none → 52.75d | resources Project Manager 1; Writer 1 → Project Manager 1; baseline start 2005-08-01 → 2005-10-31; baseline finish 2005-08-01 → 2005-10-31 |
| 2 | **Research Phase** | 2005-08-01 A → 2005-10-31 (+91d) | 2005-08-10 A → 2005-11-08 (+90d) | 8d → 7d | 100% → 0% | none → 1d | baseline start 2005-08-01 → 2005-10-31; baseline finish 2005-08-10 → 2005-11-08 |
| 3 | Interview Subject Matter Expert | 2005-08-01 A → 2005-10-31 (+91d) | 2005-08-01 A → 2005-10-31 (+91d) |  | 100% → 0% | none → 1d | resources Project Manager 1; Writer 1; Subject Matter Expert 1 → Project Manager 1; Subject Matter Expert 1; baseline start 2005-08-01 → 2005-10-31; baseline finish 2005-08-02 → 2005-10-31 |
| 4 | Investigate Unix | 2005-08-02 A → 2005-11-01 (+91d) | 2005-08-05 A → 2005-11-04 (+91d) |  | 100% → 0% | none → 1d | was named Investigate the software; baseline start 2005-08-03 → 2005-11-01; baseline finish 2005-08-08 → 2005-11-04 |
| 5 | Search the Web | 2005-08-08 A → 2005-11-07 (+91d) | 2005-08-10 A → 2005-11-08 (+90d) |  | 100% → 0% | none → 1d | resources Writer 1; Staff Assistant 1 → none; baseline start 2005-08-09 → 2005-11-07; baseline finish 2005-08-10 → 2005-11-08 |
| 6 | **Outline Phase** | 2005-08-11 A → 2005-11-09 (+90d) | 2005-08-26 A → 2005-11-23 (+89d) | 12d → 10.75d | 100% → 0% | none → 0d | baseline start 2005-08-11 → 2005-11-09; baseline finish 2005-08-23 → 2005-11-23 |
| 7 | Create outline | 2005-08-11 A → 2005-11-09 (+90d) | 2005-08-17 A → 2005-11-11 (+86d) |  | 100% → 0% | none → 1d | resources Writer 1 → none; baseline start 2005-08-11 → 2005-11-09; baseline finish 2005-08-15 → 2005-11-11 |
| 8 | Present to publisher | 2005-08-18 A → 2005-11-14 (+88d) | 2005-08-19 A → 2005-11-14 (+87d) |  | 100% → 0% | none → 1d | resources Writer 1; Project Manager 1; Publisher 1 → none; baseline start 2005-08-16 → 2005-11-14; baseline finish 2005-08-16 → 2005-11-14 |
| 9 | Review with Subject Matter Expert | 2005-08-19 A → 2005-11-15 (+88d) | 2005-08-23 A → 2005-11-17 (+86d) | 2.25d → 3d | 100% → 0% | none → 0d | constraint start no earlier than 2005-08-19 → start no earlier than 2005-11-15; resources Writer 1; Subject Matter Expert 1 → none; baseline start 2005-08-19 → 2005-11-15; baseline finish 2005-08-22 → 2005-11-17 |
| 10 | Revise outline | 2005-08-23 A → 2005-11-18 (+87d) | 2005-08-26 A → 2005-11-23 (+89d) |  | 100% → 0% | none → 0d | resources Writer 1 → none; baseline start 2005-08-23 → 2005-11-18; baseline finish 2005-08-23 → 2005-11-23 |
| 11 | **Development Phase** | 2005-08-29 A → 2005-11-23 (+86d) | 2005-10-05 A → 2006-01-06 (+93d) |  | 100% → 0% | none → 0d | baseline start 2005-08-24 → 2005-11-23; baseline finish 2005-10-05 → 2006-01-06 |
| 12 | Write content | 2005-08-29 A → 2005-11-23 (+86d) | 2005-09-28 A → 2005-12-30 (+93d) | 22d → 26.5d | 100% → 0% | none → 0d | resources Writer 1 → none; baseline start 2005-08-24 → 2005-11-23; baseline finish 2005-09-28 → 2005-12-30 |
| 13 | Add graphics | 2005-09-29 A → 2005-12-30 (+92d) | 2005-10-05 A → 2006-01-06 (+93d) |  | 100% → 0% | none → 0d | resources Artist 1; Staff Assistant 1 → none; baseline start 2005-09-29 → 2005-12-30; baseline finish 2005-10-05 → 2006-01-06 |
| 14 | **Edit Phase** | 2005-10-06 A → 2006-01-06 (+92d) | 2005-10-12 A → 2006-01-11 (+91d) | 5d → 3d | 100% → 0% | none → 0d | baseline start 2005-10-06 → 2006-01-06; baseline finish 2005-10-12 → 2006-01-11 |
| 15 | Check grammar, spelling, and proofread | 2005-10-06 A → 2006-01-06 (+92d) | 2005-10-10 A → 2006-01-11 (+93d) |  | 100% → 0% | none → 0d | resources Editor 1 → none; baseline start 2005-10-06 → 2006-01-06; baseline finish 2005-10-10 → 2006-01-11 |
| 16 | Check for technical accuracy | 2005-10-11 A → 2006-01-09 (+90d) | 2005-10-12 A → 2006-01-11 (+91d) |  | 100% → 0% | none → 0d | resources Editor 1; Subject Matter Expert 1 → none; baseline start 2005-10-11 → 2006-01-09; baseline finish 2005-10-12 → 2006-01-11 |
| 17 | **Review Phase** | 2005-10-13 A → 2006-01-11 (+90d) | 2005-10-14 A → 2006-01-13 (+91d) |  | 100% → 0% | none → 0d | baseline start 2005-10-13 → 2006-01-11; baseline finish 2005-10-14 → 2006-01-13 |
| 18 | Approve editing changes | 2005-10-13 A → 2006-01-11 (+90d) | 2005-10-13 A → 2006-01-12 (+91d) |  | 100% → 0% | none → 0d | resources Writer 1 → none; baseline start 2005-10-13 → 2006-01-11; baseline finish 2005-10-13 → 2006-01-12 |
| 19 | Meet with editor | 2005-10-14 A → 2006-01-12 (+90d) | 2005-10-14 A → 2006-01-13 (+91d) |  | 100% → 0% | none → 0d | resources Writer 1; Editor 1 → none; baseline start 2005-10-14 → 2006-01-12; baseline finish 2005-10-14 → 2006-01-13 |
| 20 | **Print Phase** | 2005-10-17 → 2006-01-13 (+88d) | 2005-10-19 → 2006-01-18 (+91d) |  |  |  | baseline start 2005-10-17 → 2006-01-13; baseline finish 2005-10-19 → 2006-01-18 |
| 21 | Print proof | 2005-10-17 → 2006-01-13 (+88d) | 2005-10-17 → 2006-01-16 (+91d) |  |  |  | resources Printer 1; Plain paper → none; baseline start 2005-10-17 → 2006-01-13; baseline finish 2005-10-17 → 2006-01-16 |
| 22 | Review proof | 2005-10-18 → 2006-01-16 (+90d) | 2005-10-18 → 2006-01-17 (+91d) |  |  |  | resources Writer 1; Editor 1; Project Manager 1 → none; baseline start 2005-10-18 → 2006-01-16; baseline finish 2005-10-18 → 2006-01-17 |
| 23 | Print final | 2005-10-19 → 2006-01-17 (+90d) | 2005-10-19 → 2006-01-18 (+91d) |  |  |  | resources Printer 1; Glossy paper → none; baseline start 2005-10-19 → 2006-01-17; baseline finish 2005-10-19 → 2006-01-18 |
| 24 | Book Complete | 2005-10-19 → 2006-01-18 (+91d) | 2005-10-19 → 2006-01-18 (+91d) |  |  |  | resources Project Manager 1; Writer 1 → none; baseline start 2005-10-19 → 2006-01-18; baseline finish 2005-10-19 → 2006-01-18 |
